# Cronograma

Schedule from MS Project, 2012-04-01 to 2013-02-25, costs in S.

## Calendars

- Estándar: Mon-Sun 07:00-12:00, 13:00-16:00.

## Resources

| Resource | Group | Unit | Rate | Cost per use |
| --- | --- | --- | --- | --- |
| TOPOGRAFO | Mano de Obra |  | 18.44 |  |
| NIVELADOR | Mano de Obra |  | 14.75 |  |
| BONIFICACION POR TRABAJOS BAJO EL AGUA | Mano de Obra |  | 8 |  |
| CAPATAZ | Mano de Obra |  | 18.44 |  |
| OPERARIO | Mano de Obra |  | 14.75 |  |
| OFICIAL | Mano de Obra |  | 12.84 |  |
| PEON | Mano de Obra |  | 11.58 |  |
| ALAMBRE NEGRO NACIONAL # 16 | Material | KG |  | 3.17 |
| ALAMBRE NEGRO NACIONAL # 8 | Material | KG |  | 3.17 |
| CLAVOS | Material | KG |  | 3.34 |
| PERNOS 3/8" X 8" | Material | und |  | 1.28 |
| PERNOS 5/8" X 14" | Material | und |  | 8.1 |
| PERNOS 3/8" X 3" | Material | und |  | 0.5 |
| PERNOS 5/8" X 6" | Material | und |  | 2.67 |
| BARRA LISA 3/4" | Material |  |  | 8.51 |
| BARRA LISA 1/2" | Material |  |  | 3.72 |
| ACERO CORRUGADO FY=4200 KG/CM2 GRADO 60 | Material | KG. |  | 3.1 |
| ALCANTARILLA METALICA DIAM 60" | Material |  |  | 826.1 |
| ALCANTARILLA METALICA DIAM 72" | Material |  |  | 1056.29 |
| ALCANTARILLA METALICA DIAM 36" | Material |  |  | 338 |
| ALCANTARILLA METALICA DIAM 48" | Material |  |  | 546.62 |
| ASFALTO DILUIDO MC-30 | Material | LT |  | 2.87 |
| EMULSION ASFALTICA DE ROTURA RAPIDA CRS-2 | Material | LT |  | 2.71 |
| CEMENTO ASFALTICO PEN 85-100 | Material | KG |  | 2.59 |
| FILLER | Material | KG |  | 0.64 |
| CEMENTO PORTLAND TIPO I | Material | BLS |  | 19.51 |
| FULMINANTE | Material | und |  | 0.71 |
| DINAMITA | Material | KG |  | 13.5 |
| MECHA | Material |  |  | 1 |
| SOLDADURA E7018 | Material | KG |  | 16.04 |
| PEGAMENTO EPOXICO | Material | KG |  | 39.09 |
| ACCESORIOS | Material | %MT |  |  |
| BARRENO 5' X 7/8" | Material | und |  | 350.79 |
| ADITIVO MEJORADOR DE ADHERENCIA | Material | KG |  | 18.44 |
| GAVION CAJA 5.0 X 1.0 X 1.0 m | Material | und |  | 364.67 |
| GAVION CAJA 5.0 X 1.5 X 1.0 m | Material | und |  | 499.77 |
| GAVION COLCHON RENO 5.0 X 2.0 X 0.3 m | Material | und |  | 384.18 |
| GAVION CAJA 5.0 X 1.0 X 0.50 m | Material | und |  | 251 |
| GAVION CAJA 5.0 X 1.5 X 0.50 m | Material | und |  | 359.22 |
| FIBRA DE VIDRIO DE 4 MM. ACABADO | Material | M2. |  | 148.08 |
| MICROESFERAS DE VIDRIO | Material | KG |  | 2.99 |
| LAMINA REFLECTORIZANTE ALTA INTENSIDAD | Material | P2 |  | 12.6 |
| GEOCOMPUESTO DE DRENAJE | Material | M2 |  | 18.23 |
| GEOTEXTIL NO TEJIDO TIPO 2 | Material | M2 |  | 3.1 |
| ADITIVO CURADOR | Material | GLN |  | 7.01 |
| ADITIVO INCORPORADOR DE AIRE | Material | GLN |  | 30.33 |
| DESMOLDANTE PARA MADERA | Material | GLN |  | 75.61 |
| TINTA SERIGRAFICA NEGRA | Material | GLN |  | 1108.87 |
| TINTA SERIGRAFICA ROJA | Material | GLN |  | 1108.87 |
| NEOPRENO EXPANDIBLE-COMPRESIBLE TIPO PANAL 5cm x 7cm | Material |  |  | 61.75 |
| ACETILENO | Material | M3 |  | 37.74 |
| TACHA | Material | und |  | 6.16 |
| PLANTAS NATIVAS | Material | KG |  | 12.42 |
| TECNOPOR DE 3/4" | Material | M2 |  | 2.12 |
| OXIGENO | Material | M3 |  | 9.52 |
| TERMINAL TIPO COLA DE PEZ | Material | und |  | 169.72 |
| TECNOPOR DE 1" | Material | M2 |  | 1.29 |
| TUBERIA CORRUGADA PERFORADA HDPE DIAM 6"X19' | Material |  |  | 19.72 |
| IMPRIMANTE PARA SELLANTES JUNTAS | Material | GLN |  | 225.62 |
| NEOPRENO 260mm x 400mm x 75mm C/LAMINAS A-36 DE 3mm | Material | und |  | 243.59 |
| NEOPRENO 150mm x 500mm x 35mm C/LAMINAS A-36 DE 2mm | Material | und |  | 109.25 |
| RELLENO CON GROUT | Material | KG |  | 2.53 |
| MALLA DE ALTA RESISTENCIA | Material | M2 |  | 46.05 |
| SELLADOR DE JUNTAS | Material | GLN |  | 160.13 |
| CORDON DE RESPALDO PARA EL SELLADO DE JUNTAS 7/8" | Material |  |  | 1.05 |
| SOLDADURA E6011 | Material | KG |  | 13.14 |
| CORDON DE RESPALDO PARA EL SELLADO DE JUNTAS 1 1/8" | Material |  |  | 1.77 |
| BARRERA DE SEGURIDAD H2 BL W3 ASI 3 ONDAS(INC. POSTES) | Material |  |  | 240.82 |
| UNION SPLIT 6" | Material | und |  | 8.5 |
| NEOPRENO 250mm x 250mm x 30mm C/LAMINAS A-36 DE 3mm | Material | und |  | 63.87 |
| MADERA TORNILLO | Material | P2 |  | 3.81 |
| TRIPLAY DE 4´ x 8´ x 18 MM. | Material | PLN |  | 89.24 |
| PERFIL 1 1/2" x 1 1/2" x 3/16" | Material |  |  | 8.3 |
| PERFIL 4" x 4" x 1/2" | Material |  |  | 75.76 |
| PERFIL 3/8" x 1" x 3/16" | Material |  |  | 2.1 |
| PLATINA DE ACERO DE 1" X 1/4" | Material |  |  | 4.49 |
| PLATINA DE ACERO DE 3" X 3/16" | Material |  |  | 10.11 |
| PLATINA DE ACERO DE 2" X 3/16" | Material |  |  | 6.7 |
| PLATINA DE ACERO DE 1" X 3/16" | Material |  |  | 3.35 |
| PLATINA DE ACERO DE 2" X 1/8" | Material |  |  | 4.52 |
| PETROLEO DIESEL 2 | Material | GLN |  | 10.91 |
| COMBUSTIBLE | Material | GLN |  | 10.54 |
| LUBRICANTES GRASAS Y FILTROS | Material | %EQ |  |  |
| PINTURA ESMALTE SINTETICO | Material | GLN |  | 37.77 |
| PINTURA BITUMINOSA | Material | GLN |  | 91.26 |
| IMPRIMANTE P/EPOXICO | Material | GLN |  | 355.23 |
| PINTURA ZINCROMATO | Material | GLN |  | 39.46 |
| IMPRIMANTE P/ MUROS | Material | GLN |  | 38.17 |
| PINTURA EPÓXICO | Material | GLN |  | 165.74 |
| THINNER STANDARD | Material | GLN |  | 29.87 |
| DISOLVENTE DE PINTURA | Material | GLN |  | 40.46 |
| DISOLVENTE P / IMPRIMANTE MURO/P.TRAFICO | Material | GLN |  | 22.04 |
| PINTURA DE TRAFICO | Material | GLN |  | 46.78 |
| PLANCHA DE ACERO 1.5 MM X 1.22 M X 2.40 M | Material | M2 |  | 39.89 |
| PLANCHA DE ACERO 16 MM X 1.22 M X 2.40 M | Material | und |  | 1268.69 |
| PLANCHA DE ACERO 9.5 MM X 1.22 M X 2.40 M | Material | und |  | 662.83 |
| PLANCHA DE ACERO 8.0 MM X 1.22 M X 2.40 M | Material | und |  | 475.82 |
| REJILLA CIRCULAR DE METAL DIAM 20cm | Material | und |  | 100.99 |
| PLANCHA DE ACERO 6 MM X 1.22 M X 2.40 M | Material | und |  | 417.26 |
| PLANCHA DE ACERO 12.5 MM X 1.22 M X 2.40 M | Material | und |  | 883.14 |
| TUBO DE FIERRO 3" | Material |  |  | 19.14 |
| TUBO DE F°G° 7/8" | Material |  |  | 6.99 |
| TUBO GALVANIZADO 1 1/2" | Material |  |  | 8.24 |
| TUBO DE F°G° 4" | Material |  |  | 49.5 |
| TUBO DE FIERRO 2" | Material |  |  | 10.79 |
| TUBERIA PVC DIAM 3" | Material |  |  | 9.24 |
| TUBERIA PVC DIAM 4" | Material |  |  | 15.22 |
| TUBERIA PVC DIAM 2" | Material |  |  | 4.27 |
| TUBERIA PVC DIAM 6" | Material |  |  | 33.6 |
| PLACA DE BRONCE | Material | und |  | 13.83 |
| HERRAMIENTAS MANUALES | Equipo |  | 8 |  |
| ANDAMIOS | Equipo |  | 1.27 |  |
| ZARANDA ESTATICA | Equipo |  | 8 |  |
| MEZCLADORA DE CONCRETO 11 P3 18 HP | Equipo |  | 9.84 |  |
| ESTACION TOTAL | Equipo |  | 15 |  |
| MOTOSIERRA | Equipo |  | 8.13 |  |
| NIVEL TOPOGRAFICO | Equipo |  | 2.75 |  |
| VOLQUETE DE 15 M3 | Equipo |  | 245.16 |  |
| EQUIPO PARA ARENAR | Equipo |  | 5.58 |  |
| CAMION CISTERNA 4X2 3 000 GAL (INC MOTOBOMBA) | Equipo |  | 173.4 |  |
| MOTOBOMBA DIAM 4" | Equipo |  | 21.96 |  |
| MOTOSOLDADORA 250 A | Equipo |  | 46.51 |  |
| EQUIPO DE OXICORTE | Equipo |  | 2.51 |  |
| CAMIONETA PICK UP 4X2 PICK UP CABINA SIMPLE 84 HP | Equipo |  | 80.39 |  |
| COMPRESORA NEUMATICA 250-330 PCM 87 HP | Equipo |  | 72.25 |  |
| RODILLO LISO VIBR AUTOP 70-100 HP 7-9 T. | Equipo |  | 91.71 |  |
| RODILLO LISO VIBRATORIO AUTOP 101-135 HP 10-12T | Equipo |  | 144.97 |  |
| COMPACTADOR TIPO PLANCHA 7 HP | Equipo |  | 24.55 |  |
| CARGADOR S/LLANTAS 125-155 HP 3 YD3. | Equipo |  | 170.16 |  |
| TRACTOR DE ORUGAS DE 190-240 HP | Equipo |  | 335.51 |  |
| EXCAVADORA SOBRE ORUGAS 115-165 HP 0.75 - 1.6 YD3 | Equipo |  | 209.88 |  |
| CARGADOR SOBRE LLANTAS 200-250 HP 4 - 4.1 YD3 | Equipo |  | 228.39 |  |
| MINICARGADOR 70 HP | Equipo |  | 63.57 |  |
| EXCAVADORA SOBRE LLANTAS 58 HP 1. YD3 | Equipo |  | 93.28 |  |
| RODILLO TANDEM VIBRATORIO AUTOPROPULSADO 111 - 130 HP 9-11 TON | Equipo |  | 82.26 |  |
| RODILLO NEUMATICO AUTOPROP 135 HP 9-26 TON | Equipo |  | 127.02 |  |
| RODILLO LISO VIBRATORIO MANUAL 10.8 HP 0.8-1.1 TON | Equipo |  | 29.54 |  |
| PAVIMENTADORA SOBRE ORUGAS 105 HP 10-16 | Equipo |  | 128.15 |  |
| PLANTA DE ASFALTO EN CALIENTE 120 TON/HS | Equipo |  | 521.36 |  |
| MARTILLO NEUMATICO DE 29 Kg. | Equipo |  | 4.03 |  |
| COMPRESORA NEUMATICA 600-690 PCM | Equipo |  | 157.46 |  |
| CHANCAD.PRIM.SECUND.5FAJAS 75HP 46-70 T | Equipo |  | 131.03 |  |
| ZARANDA VIBRATORIA 4" x 6" x 14 M.E. 15 HP | Equipo |  | 48.89 |  |
| MOTONIVELADORA 145 - 150 HP | Equipo |  | 199.66 |  |
| CORTADORA DE PAVIMENTO CON DISCO | Equipo |  | 4.07 |  |
| GRUPO ELECTROGENO 230 HP 150 KW | Equipo |  | 156.09 |  |
| MAQUINA PARA PINTAR PAVIMENTOS | Equipo |  | 40.69 |  |
| MOTOBOMBA 34 HP 8" | Equipo |  | 64.51 |  |
| CAMION GRUA DE 6 TON | Equipo |  | 120 |  |
| LAVADORA DE AGREGADO | Equipo |  | 84.18 |  |
| GRUPO ELECTROGENO 116 HP 75 KW | Equipo |  | 125.01 |  |
| GRUPO ELECTROGENO 140HP 90 KW | Equipo |  | 138.74 |  |
| CAMION IMPRIMADOR DE 1800 GLS. | Equipo |  | 125.6 |  |
| VIBRADOR DE 4 HP CAP.=1.25" | Equipo |  | 4.98 |  |
| EQUIPO DE PINTURA | Equipo |  | 24.72 |  |
| MOVILIZACION | Subcontrato | GLB |  | 830438 |
| INSTALACION DE BARRERA DE SEGURIDAD | Subcontrato |  |  | 41.16 |
| MONITOREO DE LA CALIDAD DEL AGUA | Subcontrato | PTO |  | 381.3 |
| MONITOREO DE LA CALIDAD DEL AIRE | Subcontrato | PTO |  | 1071 |
| MONITOREO DE RUIDOS | Subcontrato | PTO |  | 21 |
| MANTENIMIENTO Y SEGURIDAD VIAL | Subcontrato | EST |  | 81766.5 |

## Schedule

| ID | WBS | Task | Duration | Start | Finish | Predecessors | Total slack | Free slack | Constraint | Resources | Work | Cost | Text1 | Text8 | Text3 | Text4 | Text2 | Text6 |
| --- | --- | --- | --- | --- | --- | --- | --- | --- | --- | --- | --- | --- | --- | --- | --- | --- | --- | --- |
| 1 | 1 | **ESTUDIO DEFINITIVO DEL MEJORAMIENTO Y CONSTRUCCION DE LA CARRETERA HUAMACHUCO - PTE PALLAR** | 330d | 2012-04-01 | 2013-02-25 |  | 0d |  |  |  | 38491638h | 2,083,126,682.95 |  |  |  |  |  |  |
| 2 | 1.1 | **OBRAS PRELIMINARES** | 330d | 2012-04-01 | 2013-02-25 |  | 0d |  |  |  | 4773.81h | 1,062,262.79 | 01 | 000000000000002 |  |  |  |  |
| 3 | 1.1.1 | MOVILIZACION Y DESMOVILIZACION DE EQUIPO | 4d | 2012-04-01 | 2013-02-20 |  | 0d |  | start no earlier than 2012-04-01 | MOVILIZACION [1 GLB] |  | 830,437.81 | 01.01 | 000000000000003 | 830437.81 | 830437.81 |  |  |
| 4 | 1.1.2 | TRAZO Y REPLANTEO | 29d | 2012-04-01 | 2012-04-30 | 3SS | 0d |  | start no earlier than 2011-09-30 | CEMENTO PORTLAND TIPO I [35.12 BLS]; ADITIVO INCORPORADOR DE AIRE [0.46 GLN]; COMBUSTIBLE [1.59 GLN]; PINTURA ESMALTE SINTETICO [6.51 GLN]; THINNER STANDARD [1.08 GLN]; VOLQUETE DE 15 M3 [0.4%]; CAMION CISTERNA 4X2 3 000 GAL (INC MOTOBOMBA) [0%]; VIBRADOR DE 4 HP CAP.=1.25" [1.1%]; TOPOGRAFO [195.3%]; NIVELADOR [97.7%]; CAPATAZ [10.3%]; OPERARIO [3.4%]; OFICIAL [3.6%]; PEON [886.2%]; MEZCLADORA DE CONCRETO 11 P3 18 HP [1.1%]; ESTACION TOTAL [195.3%]; NIVEL TOPOGRAFICO [195.3%]; MOTOBOMBA DIAM 4" [0.2%]; CARGADOR S/LLANTAS 125-155 HP 3 YD3. [0.1%]; TRACTOR DE ORUGAS DE 190-240 HP [0%]; CHANCAD.PRIM.SECUND.5FAJAS 75HP 46-70 T/ [0.1%]; ZARANDA VIBRATORIA 4" x 6" x 14 M.E. 15 HP [0.1%]; LAVADORA DE AGREGADO [0.1%]; GRUPO ELECTROGENO 116 HP 75 KW [0%]; GRUPO ELECTROGENO 140HP 90 KW [0.2%]; CLAVOS [141.6 KG]; ACERO CORRUGADO FY=4200 KG/CM2 GRADO 60 [42.48 KG.]; MADERA TORNILLO [60.04 P2]; PLACA DE BRONCE [3.03 und] | 3690.12h | 44,861.61 | 01.02 | 000000000000004 | 1708.67 | 48389.53 | 28.32 |  |
| 5 | 1.1.3 | MANTENIMIENTO DE TRANSITO Y SEGURIDAD VIAL | 325d | 2012-04-06 | 2013-02-25 | 3SS+5d | 0d |  | start no earlier than 2011-09-30 | MANTENIMIENTO Y SEGURIDAD VIAL [1 EST] |  | 81,766.48 | 01.03 | 000000000000196 | 81766.48 | 899431.28 | 11 |  |
| 6 | 1.1.4 | ACCESOS A CANTERAS, DME, PLANTAS Y FUENTES DE AGUA | 5d | 2012-04-06 | 2012-04-11 | 4SS+5d | 320d |  | start no earlier than 2011-09-30 | VOLQUETE DE 15 M3 [309.2%]; CAMION CISTERNA 4X2 3 000 GAL (INC MOTOBOMBA) [82.2%]; CAPATAZ [196.2%]; OFICIAL [182.4%]; PEON [1034.6%]; RODILLO LISO VIBRATORIO AUTOP 101-135 HP 10-12T [90.2%]; CARGADOR S/LLANTAS 125-155 HP 3 YD3. [148.5%]; TRACTOR DE ORUGAS DE 190-240 HP [195.4%]; ZARANDA VIBRATORIA 4" x 6" x 14 M.E. 15 HP [190.2%]; MOTONIVELADORA 145 - 150 HP [90.2%]; GRUPO ELECTROGENO 116 HP 75 KW [190.2%] | 1083.69h | 105,196.89 | 01.04 | 000000000000006 | 23408.38 | 105571.79 | 4.51 |  |
| 7 | 1.2 | **MOVIMIENTO DE TIERRAS** | 237d | 2012-04-11 | 2012-12-04 |  | 0d |  |  |  | 14425692h | 501,996,411.55 | 02 | 000000000000007 |  |  |  |  |
| 8 | 1.2.1 | DESBROCE Y LIMPIEZA EN ZONAS NO BOSCOSAS | 16d | 2012-04-11 | 2012-04-27 | 4SS+10d | 0d |  | start no earlier than 2011-09-30 | CAPATAZ [95.1%]; OPERARIO [95.1%]; PEON [190.2%]; MOTOSIERRA [95.1%]; TRACTOR DE ORUGAS DE 190-240 HP [95.1%] | 730.56h | 48,702.78 | 02.01 | 000000000000008 | 3222.46 | 49045.84 | 15.22 |  |
| 9 | 1.2.2 | EXCAVACION EN EXPLANACIONES EN ROCA FIJA | 132d | 2012-04-16 | 2012-08-26 | 8SS+5d | 0d |  | start no earlier than 2011-09-30 | CAPATAZ [18049.3%]; OPERARIO [26387.9%]; OFICIAL [105551%]; PEON [226197%]; TRACTOR DE ORUGAS DE 190-240 HP [24171.3%]; MARTILLO NEUMATICO DE 29 Kg. [105551%]; COMPRESORA NEUMATICA 600-690 PCM [26387.9%]; DINAMITA [21110.3 KG]; MECHA; FULMINANTE [84441.1 und]; BARRENO 5' X 7/8" [1435.5 und] | 5621044h | 183,604,941.71 | 02.02 | 000000000000009 | 27.73 | 2341552.81 | 84441.14 |  |
| 10 | 1.2.3 | EXCAVACION EN EXPLANACIONES EN ROCA SUELTA | 166d | 2012-04-16 | 2012-09-29 | 9SS | 0d |  | start no earlier than 2011-09-30 | CAPATAZ [21208.9%]; OPERARIO [29253.6%]; OFICIAL [117014%]; PEON [283212%]; TRACTOR DE ORUGAS DE 190-240 HP [33276%]; MARTILLO NEUMATICO DE 29 Kg. [117014%]; COMPRESORA NEUMATICA 600-690 PCM [29253.6%]; DINAMITA [14626.8 KG]; MECHA; FULMINANTE [73134 und]; BARRENO 5' X 7/8" [585.07 und] | 8369485h | 290,127,181.51 | 02.03 | 000000000000010 | 15.73 | 2300795.95 | 146268.02 |  |
| 11 | 1.2.4 | EXCAVACION EN EXPLANACIONES EN MATERIAL COMUN | 157d | 2012-04-16 | 2012-09-20 | 9SS, 10SS | 7d | 0d | start no earlier than 2011-09-30 | CAPATAZ [49.9%]; PEON [200.2%]; TRACTOR DE ORUGAS DE 190-240 HP [59.8%]; EXCAVADORA SOBRE ORUGAS 115-165 HP 0.75 - 1.6 YD3 [39.9%] | 4392.96h | 397,969.5 | 02.04 | 000000000000011 | 4.48 | 801648.96 | 178939.5 | 570 |
| 12 | 1.2.5 | REMOCION DE DERRUMBES | 6d | 2012-09-14 | 2012-09-20 | 11FF | 158d |  | start no earlier than 2011-09-30 | VOLQUETE DE 15 M3; OFICIAL [38.9%]; CARGADOR SOBRE LLANTAS 200-250 HP 4 - 4.1 YD3 [38.9%] | 85.26h | 16,252.94 | 02.05 | 000000000000190 | 9.07 | 16280.65 | 1795 | 300 |
| 13 | 1.2.6 | CONFORMACIÓN DE TERRAPLENES | 41d | 2012-05-26 | 2012-07-06 | 9SS+40d, 10SS+40d, 11SS+40d | 14d | 0d | start no earlier than 2011-09-30 | CAMION CISTERNA 4X2 3 000 GAL (INC MOTOBOMBA) [154.2%]; CAPATAZ [98.9%]; OFICIAL [203%]; PEON [1467%]; RODILLO LISO VIBRATORIO AUTOP 101-135 HP 10-12T [98.9%]; CARGADOR S/LLANTAS 125-155 HP 3 YD3. [203%]; TRACTOR DE ORUGAS DE 190-240 HP [49.5%]; MOTONIVELADORA 145 - 150 HP [98.9%] | 7784.88h | 437,505.33 | 02.06 | 000000000000012 | 10.6 | 441017.56 | 41605.43 | 1020 |
| 14 | 1.2.7 | MEJORAMIENTO DE SUELOS A NIVEL DE SUBRASANTE | 38d | 2012-07-25 | 2012-09-01 | 11SS+100d | 177d |  | start no earlier than 2011-09-30 | CAMION CISTERNA 4X2 3 000 GAL (INC MOTOBOMBA) [1628.7%]; CAPATAZ [1674.8%]; OFICIAL [241.2%]; PEON [8300.9%]; RODILLO LISO VIBRATORIO AUTOP 101-135 HP 10-12T [1433.6%]; TRACTOR DE ORUGAS DE 190-240 HP [710.1%]; EXCAVADORA SOBRE ORUGAS 115-165 HP 0.75 - 1.6 YD3 [2384.8%]; MOTONIVELADORA 145 - 150 HP [1433.6%] | 54134.9h | 5,001,846.37 | 02.07 | 000000000000014 | 12.33 | 132157.87 | 10718.4 |  |
| 15 | 1.2.8 | PERFILADO Y COMPACTACIÓN EN ZONAS DE CORTE | 42d | 2012-05-26 | 2012-07-07 | 9SS+40d, 10SS+40d, 11SS+40d | 14d |  | start no earlier than 2011-09-30 | CAMION CISTERNA 4X2 3 000 GAL (INC MOTOBOMBA) [115.6%]; CAPATAZ [98.9%]; OFICIAL [98.9%]; PEON [511.1%]; RODILLO LISO VIBRATORIO AUTOP 101-135 HP 10-12T [98.9%]; MOTONIVELADORA 145 - 150 HP [98.9%] | 3434.78h | 212,127.65 | 02.08 | 000000000000015 | 1.67 | 213411.67 | 127791.42 | 3080 |
| 16 | 1.2.9 | PRESTAMO MATERIAL DE CANTERA | 92d | 2012-09-03 | 2012-12-04 | 29SS-5d | 83d |  | start no earlier than 2011-09-30 | CAPATAZ [3200.4%]; OFICIAL [4766.5%]; PEON [31357%]; CARGADOR S/LLANTAS 125-155 HP 3 YD3. [5447.5%]; TRACTOR DE ORUGAS DE 190-240 HP [4766.5%] | 364599h | 22,149,883.76 | 02.09 | 000000000000016 | 10.02 | 245628.98 | 24513.87 |  |
| 17 | 1.3 | **SUB BASE Y BASE** | 118d | 2012-06-24 | 2012-10-20 |  | 0d |  |  |  | 52418.9h | 3,444,217.48 | 03 | 000000000000017 |  |  |  |  |
| 18 | 1.3.1 | SUB BASE GRANULAR | 102d | 2012-06-24 | 2012-10-04 | 10FF+5d, 13SS+15d, 15SS+15d | 0d |  | start no earlier than 2011-09-30 | VOLQUETE DE 15 M3 [132.6%]; CAMION CISTERNA 4X2 3 000 GAL (INC MOTOBOMBA) [64.3%]; CAPATAZ [199.4%]; OFICIAL [179.8%]; PEON [1018.6%]; RODILLO LISO VIBRATORIO AUTOP 101-135 HP 10-12T; CARGADOR S/LLANTAS 125-155 HP 3 YD3. [148.1%]; TRACTOR DE ORUGAS DE 190-240 HP [98.7%]; ZARANDA VIBRATORIA 4" x 6" x 14 M.E. 15 HP [178.4%]; MOTONIVELADORA 145 - 150 HP; GRUPO ELECTROGENO 116 HP 75 KW [178.4%] | 19569.7h | 1,511,477.01 | 03.01 | 000000000000018 | 35.2 | 1519161.6 | 43158 | 424 |
| 19 | 1.3.2 | BASE GRANULAR | 102d | 2012-07-10 | 2012-10-20 | 18SS+16d | 0d |  | start no earlier than 2011-09-30 | VOLQUETE DE 15 M3 [108.7%]; CAMION CISTERNA 4X2 3 000 GAL (INC MOTOBOMBA) [53.9%]; CAPATAZ [132.8%]; OFICIAL [404.1%]; PEON [2155.2%]; RODILLO LISO VIBRATORIO AUTOP 101-135 HP 10-12T [99.3%]; CARGADOR S/LLANTAS 125-155 HP 3 YD3. [121.4%]; TRACTOR DE ORUGAS DE 190-240 HP [80.9%]; CHANCAD.PRIM.SECUND.5FAJAS 75HP 46-70 T/ [256.7%]; ZARANDA VIBRATORIA 4" x 6" x 14 M.E. 15 HP [256.7%]; MOTONIVELADORA 145 - 150 HP [99.3%]; GRUPO ELECTROGENO 230 HP 150 KW [256.7%] | 32849.2h | 1,932,740.47 | 03.02 | 000000000000019 | 53.83 | 1946761.95 | 36165 | 357 |
| 20 | 1.4 | **PAVIMENTO ASFALTICO** | 57d | 2012-09-09 | 2012-11-05 |  | 42d |  |  |  | 31431.5h | 1,928,105.72 | 04 | 000000000000020 |  |  |  |  |
| 21 | 1.4.1 | IMPRIMACION ASFALTICA | 51d | 2012-09-09 | 2012-10-30 | 19FF+10d | 42d | 0d | start no earlier than 2011-09-30 | VOLQUETE DE 15 M3 [5.1%]; COMPRESORA NEUMATICA 250-330 PCM 87 HP [99.5%]; CAMION IMPRIMADOR DE 1800 GLS. [99.5%]; CAPATAZ [104.1%]; OPERARIO [8.5%]; OFICIAL [16.3%]; PEON [629.7%]; MOTOBOMBA DIAM 4" [18.7%]; CARGADOR S/LLANTAS 125-155 HP 3 YD3. [8.2%]; TRACTOR DE ORUGAS DE 190-240 HP [3.8%]; MINICARGADOR 70 HP [99.5%]; ZARANDA VIBRATORIA 4" x 6" x 14 M.E. 15 HP [6.8%]; LAVADORA DE AGREGADO [8.5%]; GRUPO ELECTROGENO 116 HP 75 KW [6.8%]; GRUPO ELECTROGENO 140HP 90 KW [8.5%] | 4584.42h | 175,326.69 | 04.01 | 000000000000021 | 0.78 | 175889.22 | 225499 | 4500 |
| 22 | 1.4.2 | PAVIMENTO DE CONCRETO ASFALTICO EN CALIENTE | 52d | 2012-09-14 | 2012-11-05 | 21SS+5d | 42d | 0d | start no earlier than 2011-09-30 | PETROLEO DIESEL 2 [131882 GLN]; VOLQUETE DE 15 M3 [113.9%]; CAPATAZ [308.9%]; OPERARIO [420.1%]; OFICIAL [665.2%]; PEON [2362.2%]; MOTOBOMBA DIAM 4" [419.9%]; CARGADOR S/LLANTAS 125-155 HP 3 YD3. [184.8%]; TRACTOR DE ORUGAS DE 190-240 HP [84.8%]; CARGADOR SOBRE LLANTAS 200-250 HP 4 - 4.1 YD3 [41.5%]; RODILLO TANDEM VIBRATORIO AUTOPROPULSADO 111 - 130 HP 9-11 TON; RODILLO NEUMATICO AUTOPROP 135 HP 9-26 TON; PAVIMENTADORA SOBRE ORUGAS 105 HP 10-16; PLANTA DE ASFALTO EN CALIENTE 120 TON/HS [129.5%]; CHANCAD.PRIM.SECUND.5FAJAS 75HP 46-70 T/ [170.8%]; ZARANDA VIBRATORIA 4" x 6" x 14 M.E. 15 HP [241.5%]; GRUPO ELECTROGENO 230 HP 150 KW [258.5%]; LAVADORA DE AGREGADO [190.9%]; GRUPO ELECTROGENO 116 HP 75 KW [200.2%]; GRUPO ELECTROGENO 140HP 90 KW [361.7%] | 26847.1h | 1,752,754.5 | 04.02 | 000000000000022 | 183.07 | 3202077.37 | 17491 | 338 |
| 23 | 1.4.3 | CEMENTO ASFALTICO PEN 85 - 100 | 52d | 2012-09-14 | 2012-11-05 | 21SS+5d | 112d |  | start no earlier than 2011-09-30 | CEMENTO ASFALTICO PEN 85-100 [2.42076e+06 KG] |  | 2.59 | 04.03 | 000000000000023 | 2.59 | 6269778.76 | 2420764 |  |
| 24 | 1.4.4 | ASFALTO DILUIDO MC-30 | 52d | 2012-09-14 | 2012-11-05 | 22FF | 112d |  | start no earlier than 2011-09-30 | ASFALTO DILUIDO MC-30 [256055 LT] |  | 2.87 | 04.04 | 000000000000024 | 2.87 | 734877.85 | 256055 |  |
| 25 | 1.4.5 | FILLER MINERAL (CAL HIDRATADA) | 52d | 2012-09-14 | 2012-11-05 | 22FF | 112d |  | start no earlier than 2011-09-30 | FILLER [759112 KG] |  | 0.64 | 04.05 | 000000000000025 | 0.64 | 485831.68 | 759112 |  |
| 26 | 1.4.6 | ADITIVO MEJORADOR DE ADHERENCIA | 52d | 2012-09-14 | 2012-11-05 | 22FF | 112d |  | start no earlier than 2011-09-30 | ADITIVO MEJORADOR DE ADHERENCIA [12104 KG] |  | 18.44 | 04.06 | 000000000000026 | 18.44 | 223197.76 | 12104 |  |

| ID | WBS | Task | Duration | Start | Finish | Predecessors | Total slack | Free slack | Constraint | Resources | Work | Cost | Text1 | Text8 | Text2 | Text3 | Text4 | Text6 |
| --- | --- | --- | --- | --- | --- | --- | --- | --- | --- | --- | --- | --- | --- | --- | --- | --- | --- | --- |
| 27 | 1.5 | **OBRAS DE ARTE Y DRENAJE** | 309d | 2012-04-22 | 2013-02-25 |  | 0d |  |  |  | 16657196h | 238,898,746.57 | 05 | 000000000000027 |  |  |  |  |
| 28 | 1.5.1 | EXCAVACION PARA ESTRUCTURAS EN MATERIAL COMUN EN SECO | 51d | 2012-06-25 | 2012-08-15 | 9SS+70d, 10SS+70d, 11SS+70d | 20d | 0d | start no earlier than 2011-09-30 | COMPRESORA NEUMATICA 250-330 PCM 87 HP [29.9%]; CAPATAZ [10%]; PEON [398.6%]; EXCAVADORA SOBRE LLANTAS 58 HP 1. YD3; MARTILLO NEUMATICO DE 29 Kg. [59.8%]; BARRENO 5' X 7/8" [5.04 und] | 2439.48h | 67,654.83 | 05.01 | 000000000000028 | 25211.95 | 13.5 | 340361.33 | 100 |
| 29 | 1.5.2 | RELLENOS PARA ESTRUCTURAS | 78d | 2012-09-08 | 2012-11-25 | 40SS+30d | 92d | 0d | start no earlier than 2011-09-30 | CAMION CISTERNA 4X2 3 000 GAL (INC MOTOBOMBA) [7.6%]; CAPATAZ [10%]; OFICIAL; PEON [306.4%]; COMPACTADOR TIPO PLANCHA 7 HP [199.2%]; RODILLO LISO VIBRATORIO MANUAL 10.8 HP 0.8-1.1 TON | 4507.91h | 88,342.33 | 05.02 | 000000000000029 | 11555.63 | 23.15 | 267512.83 | 50 |
| 30 | 1.5.3 | FILTRO DRENANTE | 16d | 2012-08-26 | 2012-09-11 | 43FF | 167d |  | start no earlier than 2011-09-30 | VOLQUETE DE 15 M3 [94.6%]; CAPATAZ [24.2%]; OPERARIO [26.1%]; OFICIAL [57%]; PEON [515.5%]; MOTOBOMBA DIAM 4" [57.5%]; CARGADOR S/LLANTAS 125-155 HP 3 YD3. [32.4%]; TRACTOR DE ORUGAS DE 190-240 HP [11.6%]; ZARANDA VIBRATORIA 4" x 6" x 14 M.E. 15 HP [21%]; LAVADORA DE AGREGADO [26.1%]; GRUPO ELECTROGENO 116 HP 75 KW [21%]; GRUPO ELECTROGENO 140HP 90 KW [26.1%] | 1168.77h | 65,097.07 | 05.03 | 000000000000030 | 796.06 | 82.42 | 65611.27 | 50 |
| 31 | 1.5.4 | CONCRETO CLASE C (F´c = 280 Kg/cm2) | 37d | 2012-07-25 | 2012-08-31 | 38SS+5d | 108d | 0d | start no earlier than 2011-09-30 | CEMENTO PORTLAND TIPO I [7305.87 BLS]; ADITIVO INCORPORADOR DE AIRE [95.97 GLN]; COMBUSTIBLE [185.97 GLN]; VOLQUETE DE 15 M3 [34.2%]; CAMION CISTERNA 4X2 3 000 GAL (INC MOTOBOMBA) [3.9%]; VIBRADOR DE 4 HP CAP.=1.25"; CAPATAZ [53.6%]; OPERARIO [308.8%]; OFICIAL [328.2%]; PEON [668.7%]; MEZCLADORA DE CONCRETO 11 P3 18 HP; MOTOBOMBA DIAM 4" [21.1%]; CARGADOR S/LLANTAS 125-155 HP 3 YD3. [11.9%]; TRACTOR DE ORUGAS DE 190-240 HP [4.3%]; CHANCAD.PRIM.SECUND.5FAJAS 75HP 46-70 T/ [8.1%]; ZARANDA VIBRATORIA 4" x 6" x 14 M.E. 15 HP [11.2%]; LAVADORA DE AGREGADO [9.6%]; GRUPO ELECTROGENO 116 HP 75 KW [3.1%]; GRUPO ELECTROGENO 140HP 90 KW [17.7%] | 4983.96h | 110,226.61 | 05.04 | 000000000000031 | 664.17 | 392.07 | 260401.13 | 18 |
| 32 | 1.5.5 | CONCRETO CLASE D (F´c = 210 Kg/cm2) | 76d | 2012-07-25 | 2012-10-09 | 38SS+5d | 139d | 0d | start no earlier than 2011-09-30 | CEMENTO PORTLAND TIPO I [24317.9 BLS]; ADITIVO INCORPORADOR DE AIRE [319.38 GLN]; COMBUSTIBLE [756.56 GLN]; VOLQUETE DE 15 M3 [34.1%]; CAMION CISTERNA 4X2 3 000 GAL (INC MOTOBOMBA) [3.9%]; VIBRADOR DE 4 HP CAP.=1.25" [99.4%]; CAPATAZ [53.4%]; OPERARIO [307.8%]; OFICIAL [327.2%]; PEON [666.6%]; MEZCLADORA DE CONCRETO 11 P3 18 HP [99.4%]; MOTOBOMBA DIAM 4" [21.1%]; CARGADOR S/LLANTAS 125-155 HP 3 YD3. [11.8%]; TRACTOR DE ORUGAS DE 190-240 HP [4.3%]; CHANCAD.PRIM.SECUND.5FAJAS 75HP 46-70 T/ [8.1%]; ZARANDA VIBRATORIA 4" x 6" x 14 M.E. 15 HP [11.2%]; LAVADORA DE AGREGADO [9.6%]; GRUPO ELECTROGENO 116 HP 75 KW [3.1%]; GRUPO ELECTROGENO 140HP 90 KW [17.7%] | 10205.1h | 225,634.69 | 05.05 | 000000000000032 | 2701.99 | 352.26 | 951803 | 18 |
| 33 | 1.5.6 | CONCRETO CLASE E (F´c = 175 Kg/cm2) | 34d | 2012-07-25 | 2012-08-28 | 38SS+5d | 128d | 0d | start no earlier than 2011-09-30 | CEMENTO PORTLAND TIPO I [4488.9 BLS]; ADITIVO INCORPORADOR DE AIRE [58.95 GLN]; COMBUSTIBLE [167.59 GLN]; VOLQUETE DE 15 M3 [33.6%]; CAMION CISTERNA 4X2 3 000 GAL (INC MOTOBOMBA) [3.8%]; VIBRADOR DE 4 HP CAP.=1.25" [97.8%]; CAPATAZ [52.5%]; OPERARIO [302.8%]; OFICIAL [321.9%]; PEON [655.8%]; MEZCLADORA DE CONCRETO 11 P3 18 HP [97.8%]; MOTOBOMBA DIAM 4" [20.7%]; CARGADOR S/LLANTAS 125-155 HP 3 YD3. [11.6%]; TRACTOR DE ORUGAS DE 190-240 HP [4.2%]; CHANCAD.PRIM.SECUND.5FAJAS 75HP 46-70 T/ [8%]; ZARANDA VIBRATORIA 4" x 6" x 14 M.E. 15 HP [11%]; LAVADORA DE AGREGADO [9.4%]; GRUPO ELECTROGENO 116 HP 75 KW [3%]; GRUPO ELECTROGENO 140HP 90 KW [17.4%] | 4491.32h | 99,337.18 | 05.06 | 000000000000133 | 598.52 | 322.4 | 192962.85 | 18 |
| 34 | 1.5.7 | CONCRETO CLASE F (F´C =140 Kg/cm2 ) | 1d | 2012-09-10 | 2012-09-11 | 44SS | 167d |  | start no earlier than 2011-09-30 | CEMENTO PORTLAND TIPO I [8.68 BLS]; ADITIVO INCORPORADOR DE AIRE [0.11 GLN]; COMBUSTIBLE [0.39 GLN]; VOLQUETE DE 15 M3 [2.7%]; CAMION CISTERNA 4X2 3 000 GAL (INC MOTOBOMBA) [0.3%]; VIBRADOR DE 4 HP CAP.=1.25" [7.8%]; CAPATAZ [4.2%]; OPERARIO [24.1%]; OFICIAL [25.6%]; PEON [52.2%]; MEZCLADORA DE CONCRETO 11 P3 18 HP [7.8%]; MOTOBOMBA DIAM 4" [1.6%]; CARGADOR S/LLANTAS 125-155 HP 3 YD3. [0.9%]; TRACTOR DE ORUGAS DE 190-240 HP [0.3%]; CHANCAD.PRIM.SECUND.5FAJAS 75HP 46-70 T/ [0.6%]; ZARANDA VIBRATORIA 4" x 6" x 14 M.E. 15 HP [0.9%]; LAVADORA DE AGREGADO [0.8%]; GRUPO ELECTROGENO 116 HP 75 KW [0.2%]; GRUPO ELECTROGENO 140HP 90 KW [1.4%] | 10.51h | 292.65 | 05.07 | 000000000000033 | 1.4 | 296.51 | 415.11 | 18 |
| 35 | 1.5.8 | CONCRETO CLASE F1 (F´c = 100 Kg/cm2 ) | 19d | 2012-07-10 | 2012-07-29 | 28SS+15d | 20d | 0d | start no earlier than 2011-09-30 | CEMENTO PORTLAND TIPO I [2049.48 BLS]; ADITIVO INCORPORADOR DE AIRE [26.92 GLN]; COMBUSTIBLE [127.52 GLN]; VOLQUETE DE 15 M3 [45.7%]; CAMION CISTERNA 4X2 3 000 GAL (INC MOTOBOMBA) [5.2%]; VIBRADOR DE 4 HP CAP.=1.25" [95.9%]; CAPATAZ [52.9%]; OPERARIO [300.5%]; OFICIAL [326.4%]; PEON [669.2%]; MEZCLADORA DE CONCRETO 11 P3 18 HP [95.9%]; MOTOBOMBA DIAM 4" [28.2%]; CARGADOR S/LLANTAS 125-155 HP 3 YD3. [15.8%]; TRACTOR DE ORUGAS DE 190-240 HP [5.7%]; CHANCAD.PRIM.SECUND.5FAJAS 75HP 46-70 T/ [10.8%]; ZARANDA VIBRATORIA 4" x 6" x 14 M.E. 15 HP [15%]; LAVADORA DE AGREGADO [12.8%]; GRUPO ELECTROGENO 116 HP 75 KW [4.1%]; GRUPO ELECTROGENO 140HP 90 KW [23.7%] | 2595.89h | 65,613.58 | 05.08 | 000000000000035 | 455.44 | 239.63 | 109137.09 | 25 |
| 36 | 1.5.9 | CONCRETO CLASE G (F´c = 175 Kg/cm2 + 30% PM) | 51d | 2012-07-25 | 2012-09-14 | 38SS+5d | 164d | 10d | start no earlier than 2011-09-30 | CEMENTO PORTLAND TIPO I [9524.29 BLS]; ADITIVO INCORPORADOR DE AIRE [125.09 GLN]; COMBUSTIBLE [355.57 GLN]; VOLQUETE DE 15 M3 [34.8%]; CAMION CISTERNA 4X2 3 000 GAL (INC MOTOBOMBA) [2.7%]; VIBRADOR DE 4 HP CAP.=1.25" [69.8%]; CAPATAZ [37.5%]; OPERARIO [216.3%]; OFICIAL [231.1%]; PEON [1075.4%]; MEZCLADORA DE CONCRETO 11 P3 18 HP [69.8%]; MOTOBOMBA DIAM 4" [14.8%]; CARGADOR S/LLANTAS 125-155 HP 3 YD3. [9.5%]; TRACTOR DE ORUGAS DE 190-240 HP [3%]; CHANCAD.PRIM.SECUND.5FAJAS 75HP 46-70 T/ [5.7%]; ZARANDA VIBRATORIA 4" x 6" x 14 M.E. 15 HP [7.9%]; LAVADORA DE AGREGADO [6.7%]; GRUPO ELECTROGENO 116 HP 75 KW [2.2%]; GRUPO ELECTROGENO 140HP 90 KW [12.4%] | 7342.47h | 146,851.12 | 05.09 | 000000000000034 | 1814.15 | 271.38 | 492324.03 | 18 |
| 37 | 1.5.10 | CONCRETO CLASE G1 (F´c = 140 Kg/cm2 + 30% PM) | 3d | 2012-07-30 | 2012-08-02 | 32SS+5d | 207d |  | start no earlier than 2011-09-30 | CEMENTO PORTLAND TIPO I [183.76 BLS]; ADITIVO INCORPORADOR DE AIRE [2.42 GLN]; COMBUSTIBLE [8.3 GLN]; VOLQUETE DE 15 M3 [27.4%]; CAMION CISTERNA 4X2 3 000 GAL (INC MOTOBOMBA) [2.1%]; VIBRADOR DE 4 HP CAP.=1.25" [54.9%]; CAPATAZ [29.5%]; OPERARIO [169.9%]; OFICIAL [181.6%]; PEON [845%]; MEZCLADORA DE CONCRETO 11 P3 18 HP [54.9%]; MOTOBOMBA DIAM 4" [11.6%]; CARGADOR S/LLANTAS 125-155 HP 3 YD3. [7.5%]; TRACTOR DE ORUGAS DE 190-240 HP [2.3%]; CHANCAD.PRIM.SECUND.5FAJAS 75HP 46-70 T/ [4.5%]; ZARANDA VIBRATORIA 4" x 6" x 14 M.E. 15 HP [6.2%]; LAVADORA DE AGREGADO [5.3%]; GRUPO ELECTROGENO 116 HP 75 KW [1.7%]; GRUPO ELECTROGENO 140HP 90 KW [9.8%] | 339.37h | 6,844.98 | 05.10 | 000000000000134 | 42.34 | 253.26 | 10723.03 | 18 |
| 38 | 1.5.11 | ENCOFRADO Y DESENCOFRADO | 200d | 2012-07-20 | 2013-02-05 | 39SS+5d | 20d | 0d | start no earlier than 2011-09-30 | ADITIVO CURADOR [756.09 GLN]; DESMOLDANTE PARA MADERA [934.19 GLN]; CAPATAZ [11992.4%]; OPERARIO [120008%]; OFICIAL [120008%]; PEON [240037%]; ALAMBRE NEGRO NACIONAL # 8 [3360.39 KG]; CLAVOS [3360.39 KG]; MADERA TORNILLO [42004.8 P2]; TRIPLAY DE 4´ x 8´ x 18 MM. [1344.15 PLN] | 7872712h | 100,988,626 | 05.11 | 000000000000036 | 16801.93 | 54.04 | 907976.3 | 14 |
| 39 | 1.5.12 | ACERO DE REFUERZO FY=4200 KG/CM2 | 151d | 2012-07-15 | 2012-12-13 | 35SS+5d | 20d | 0d | start no earlier than 2011-09-30 | CAPATAZ [7552.4%]; OPERARIO [75524.4%]; OFICIAL [75524.4%]; PEON [75524.4%]; ALAMBRE NEGRO NACIONAL # 16 [9440.55 KG]; ACERO CORRUGADO FY=4200 KG/CM2 GRADO 60 [198252 KG.] | 2828239h | 37,418,521.78 | 05.12 | 000000000000037 | 188811.09 | 4.8 | 906293.23 | 250 |
| 40 | 1.5.13 | TUBERIA METALICA CORRUGADA CIRCULAR D=0.90 m | 37d | 2012-08-09 | 2012-09-15 | 28SS+45d | 92d | 0d | start no earlier than 2011-09-30 | VOLQUETE DE 15 M3 [0.8%]; CAMION CISTERNA 4X2 3 000 GAL (INC MOTOBOMBA) [0.4%]; CAPATAZ [99.3%]; OPERARIO [197.3%]; OFICIAL [1.1%]; PEON [595.7%]; COMPACTADOR TIPO PLANCHA 7 HP [49.3%]; CARGADOR S/LLANTAS 125-155 HP 3 YD3. [0.9%]; TRACTOR DE ORUGAS DE 190-240 HP [0.6%]; ZARANDA VIBRATORIA 4" x 6" x 14 M.E. 15 HP [1.1%]; GRUPO ELECTROGENO 116 HP 75 KW [1.1%]; ALCANTARILLA METALICA DIAM 36" [51100%] | 2804.79h | 40,823.29 | 05.13 | 000000000000038 | 511 | 420.61 | 214931.71 | 14 |
| 41 | 1.5.14 | TUBERIA METALICA CORRUGADA CIRCULAR D=1.20 m | 29d | 2012-09-15 | 2012-10-14 | 40 | 127d | 0d | start no earlier than 2011-09-30 | VOLQUETE DE 15 M3 [0.8%]; CAMION CISTERNA 4X2 3 000 GAL (INC MOTOBOMBA) [0.4%]; CAPATAZ; OPERARIO [199.6%]; OFICIAL [1.1%]; PEON [602.7%]; COMPACTADOR TIPO PLANCHA 7 HP [49.9%]; CARGADOR S/LLANTAS 125-155 HP 3 YD3. [0.9%]; TRACTOR DE ORUGAS DE 190-240 HP [0.6%]; ZARANDA VIBRATORIA 4" x 6" x 14 M.E. 15 HP [1.1%]; GRUPO ELECTROGENO 116 HP 75 KW [1.1%]; ALCANTARILLA METALICA DIAM 48" [34730%] | 2224.66h | 32,707.27 | 05.14 | 000000000000039 | 347.3 | 643.16 | 223369.47 | 12 |
| 42 | 1.5.15 | TUBERIA METALICA CORRUGADA CIRCULAR D=1.50 m | 7d | 2012-10-14 | 2012-10-21 | 41 | 127d |  | start no earlier than 2011-09-30 | VOLQUETE DE 15 M3 [0.9%]; CAMION CISTERNA 4X2 3 000 GAL (INC MOTOBOMBA) [0.4%]; CAPATAZ [97.5%]; OPERARIO [193.7%]; OFICIAL [1.2%]; PEON [585.1%]; COMPACTADOR TIPO PLANCHA 7 HP [48.4%]; CARGADOR S/LLANTAS 125-155 HP 3 YD3. [1%]; TRACTOR DE ORUGAS DE 190-240 HP [0.6%]; ZARANDA VIBRATORIA 4" x 6" x 14 M.E. 15 HP [1.1%]; GRUPO ELECTROGENO 116 HP 75 KW [1.1%]; ALCANTARILLA METALICA DIAM 60" [6780%] | 521.41h | 8,381.09 | 05.15 | 000000000000135 | 67.8 | 942.26 | 63885.23 | 10 |
| 43 | 1.5.16 | SUBDREN PROFUNDO | 68d | 2012-07-05 | 2012-09-11 | 28SS+10d | 167d | 0d | start no earlier than 2011-09-30 | VOLQUETE DE 15 M3 [110.8%]; CAPATAZ [24.2%]; OPERARIO [25.1%]; OFICIAL [157.3%]; PEON [315.6%]; MOTOBOMBA DIAM 4" [55.3%]; CARGADOR S/LLANTAS 125-155 HP 3 YD3. [33.6%]; TRACTOR DE ORUGAS DE 190-240 HP [11.7%]; ZARANDA VIBRATORIA 4" x 6" x 14 M.E. 15 HP [21.1%]; LAVADORA DE AGREGADO [25.1%]; GRUPO ELECTROGENO 116 HP 75 KW [21.1%]; GRUPO ELECTROGENO 140HP 90 KW [25.1%] | 4493.27h | 292,471.62 | 05.16 | 000000000000040 | 4075.92 | 72.21 | 294322.18 | 60 |
| 44 | 1.5.17 | DESCARGA TRANSVERSAL DE SUBDREN | 1d | 2012-09-10 | 2012-09-11 | 43FF | 167d | 0d | start no earlier than 2011-09-30 | VOLQUETE DE 15 M3 [19.6%]; CAPATAZ [4.2%]; OPERARIO [4.5%]; OFICIAL [27.9%]; PEON [55.9%]; MOTOBOMBA DIAM 4" [10%]; COMPACTADOR TIPO PLANCHA 7 HP [17.7%]; CARGADOR S/LLANTAS 125-155 HP 3 YD3. [5.9%]; TRACTOR DE ORUGAS DE 190-240 HP [2%]; ZARANDA VIBRATORIA 4" x 6" x 14 M.E. 15 HP [3.7%]; LAVADORA DE AGREGADO [4.5%]; GRUPO ELECTROGENO 116 HP 75 KW [3.7%]; GRUPO ELECTROGENO 140HP 90 KW [4.5%] | 13.13h | 794.8 | 05.17 | 000000000000041 | 10.62 | 75.29 | 799.58 | 60 |
| 45 | 1.5.18 | TUBO DE PVC SAP D=6" | 1d | 2012-09-10 | 2012-09-11 | 44FF | 167d |  | start no earlier than 2011-09-30 | CAPATAZ [7%]; OPERARIO [70%]; PEON [70%]; TUBERIA PVC DIAM 6" [7350%] | 11.76h | 191.37 | 05.18 | 000000000000169 | 70 | 41.18 | 2882.6 | 100 |
| 46 | 1.5.19 | TUBO DE PVC SAP D=3" | 9d | 2012-09-15 | 2012-09-24 | 32FF-15d, 36FF | 154d |  | start no earlier than 2011-09-30 | CAPATAZ [10%]; OPERARIO; PEON; TUBERIA PVC DIAM 3" [113130%] | 150.95h | 2,034.55 | 05.19 | 000000000000044 | 1077.43 | 12.63 | 13607.94 | 120 |
| 47 | 1.5.20 | TUBERIA CORRUGADA PERFORADA HDPE, D=6" | 77d | 2012-06-26 | 2012-09-11 | 43FF | 167d | 0d | start no earlier than 2011-09-30 | CAPATAZ [9.9%]; OPERARIO [98.8%]; PEON [98.8%]; TUBERIA CORRUGADA PERFORADA HDPE DIAM 6"X19' [718915%]; UNION SPLIT 6" [1126.3 und] | 1278.3h | 17,178.47 | 05.20 | 000000000000042 | 6846.81 | 24.74 | 169390.08 | 90 |
| 48 | 1.5.21 | TUBERIA DE VENTILACION | 1d | 2012-09-10 | 2012-09-11 | 47FF | 167d |  | start no earlier than 2011-09-30 | CAPATAZ [6%]; OPERARIO [60%]; PEON [60%]; TUBO GALVANIZADO 1 1/2" [6000%] | 10.08h | 143.48 | 05.21 | 000000000000045 | 60 | 11.43 | 685.8 | 100 |
| 49 | 1.5.22 | CUNETA TRIANGULAR | 123d | 2012-08-09 | 2012-12-10 | 19SS+30d | 0d |  | start no earlier than 2011-09-30 | CEMENTO PORTLAND TIPO I [32907.2 BLS]; ADITIVO INCORPORADOR DE AIRE [432.18 GLN]; DESMOLDANTE PARA MADERA [73.08 GLN]; IMPRIMANTE PARA SELLANTES JUNTAS [46.86 GLN]; SELLADOR DE JUNTAS [643.34 GLN]; COMBUSTIBLE [1228.53 GLN]; VOLQUETE DE 15 M3 [49.7%]; CAMION CISTERNA 4X2 3 000 GAL (INC MOTOBOMBA) [8.3%]; VIBRADOR DE 4 HP CAP.=1.25" [99.5%]; CAPATAZ [139.6%]; OPERARIO [350.7%]; OFICIAL [406.1%]; PEON [1960.9%]; MEZCLADORA DE CONCRETO 11 P3 18 HP [99.5%]; MOTOBOMBA DIAM 4" [21.1%]; COMPACTADOR TIPO PLANCHA 7 HP [193.2%]; CARGADOR S/LLANTAS 125-155 HP 3 YD3. [14.6%]; TRACTOR DE ORUGAS DE 190-240 HP [4.3%]; CHANCAD.PRIM.SECUND.5FAJAS 75HP 46-70 T/ [8.1%]; ZARANDA VIBRATORIA 4" x 6" x 14 M.E. 15 HP [11.2%]; LAVADORA DE AGREGADO [9.6%]; GRUPO ELECTROGENO 116 HP 75 KW [3.1%]; GRUPO ELECTROGENO 140HP 90 KW [17.7%]; ALAMBRE NEGRO NACIONAL # 8 [292.31 KG]; CLAVOS [292.31 KG]; CORDON DE RESPALDO PARA EL SELLADO DE JUNTAS 7/8"; TECNOPOR DE 3/4" [1462.39 M2]; MADERA TORNILLO [6577.04 P2]; TRIPLAY DE 4´ x 8´ x 18 MM. [146.16 PLN] | 33426h | 641,622.68 | 05.22 | 000000000000046 | 29289.85 | 73.68 | 2158076.15 | 120 |
| 50 | 1.5.23 | CANAL DE RIEGO | 13d | 2012-12-10 | 2012-12-23 | 49 | 64d |  | start no earlier than 2011-09-30 | CEMENTO PORTLAND TIPO I [1039.12 BLS]; ADITIVO INCORPORADOR DE AIRE [13.65 GLN]; DESMOLDANTE PARA MADERA [39.21 GLN]; IMPRIMANTE PARA SELLANTES JUNTAS [1.27 GLN]; SELLADOR DE JUNTAS [15.89 GLN]; COMBUSTIBLE [38.79 GLN]; VOLQUETE DE 15 M3 [576.2%]; CAMION CISTERNA 4X2 3 000 GAL (INC MOTOBOMBA) [54.6%]; VIBRADOR DE 4 HP CAP.=1.25" [769.6%]; CAPATAZ [2008.4%]; OPERARIO [7984.9%]; OFICIAL [8394.8%]; PEON [28909.6%]; MEZCLADORA DE CONCRETO 11 P3 18 HP [769.6%]; MOTOBOMBA DIAM 4" [163.1%]; COMPACTADOR TIPO PLANCHA 7 HP [1086.4%]; CARGADOR S/LLANTAS 125-155 HP 3 YD3. [147.6%]; TRACTOR DE ORUGAS DE 190-240 HP [32.9%]; CHANCAD.PRIM.SECUND.5FAJAS 75HP 46-70 T/ [62.7%]; ZARANDA VIBRATORIA 4" x 6" x 14 M.E. 15 HP [86.5%]; LAVADORA DE AGREGADO [74.1%]; GRUPO ELECTROGENO 116 HP 75 KW [23.8%]; GRUPO ELECTROGENO 140HP 90 KW [136.8%]; ALAMBRE NEGRO NACIONAL # 8 [156.85 KG]; CLAVOS [156.85 KG]; CORDON DE RESPALDO PARA EL SELLADO DE JUNTAS 1 1/8" [38142%]; TECNOPOR DE 1" [62.35 M2]; MADERA TORNILLO [3529.24 P2]; TRIPLAY DE 4´ x 8´ x 18 MM. [78.43 PLN] | 53332.9h | 901,841.53 | 05.23 | 000000000000048 | 815 | 148.3 | 120864.5 |  |
| 51 | 1.5.24 | CUNETA CANAL CON TAPA | 77d | 2012-12-10 | 2013-02-25 | 49 | 0d |  | start no earlier than 2011-09-30 | CEMENTO PORTLAND TIPO I [22830.3 BLS]; ADITIVO INCORPORADOR DE AIRE [299.86 GLN]; DESMOLDANTE PARA MADERA [475 GLN]; IMPRIMANTE PARA SELLANTES JUNTAS [3.37 GLN]; SELLADOR DE JUNTAS [42.16 GLN]; COMBUSTIBLE [702.91 GLN]; VOLQUETE DE 15 M3 [7552.2%]; CAMION CISTERNA 4X2 3 000 GAL (INC MOTOBOMBA) [712.9%]; VIBRADOR DE 4 HP CAP.=1.25" [13592.2%]; CAPATAZ [27942.3%]; OPERARIO [162081%]; OFICIAL [165836%]; PEON [380839%]; MEZCLADORA DE CONCRETO 11 P3 18 HP [13592.2%]; MOTOBOMBA DIAM 4" [2954.3%]; COMPACTADOR TIPO PLANCHA 7 HP [7566%]; CARGADOR S/LLANTAS 125-155 HP 3 YD3. [2154.8%]; TRACTOR DE ORUGAS DE 190-240 HP [596.9%]; CHANCAD.PRIM.SECUND.5FAJAS 75HP 46-70 T/ [1135.9%]; ZARANDA VIBRATORIA 4" x 6" x 14 M.E. 15 HP [1567.4%]; LAVADORA DE AGREGADO [1343.1%]; GRUPO ELECTROGENO 116 HP 75 KW [431.5%]; GRUPO ELECTROGENO 140HP 90 KW [2478.9%]; ALAMBRE NEGRO NACIONAL # 16 [6513.14 KG]; ALAMBRE NEGRO NACIONAL # 8 [1899.98 KG]; CLAVOS [1899.98 KG]; ACERO CORRUGADO FY=4200 KG/CM2 GRADO 60 [136776 KG.]; CORDON DE RESPALDO PARA EL SELLADO DE JUNTAS 1 1/8" [101194%]; TECNOPOR DE 1" [165.41 M2]; MADERA TORNILLO [42749.6 P2]; TRIPLAY DE 4´ x 8´ x 18 MM. [949.99 PLN] | 4881039h | 81,164,084.57 | 05.24 | 000000000000128 | 6486.8 | 355.45 | 2305733.06 |  |
| 52 | 1.5.25 | CANAL ALIVIADERO | 45d | 2013-01-04 | 2013-02-18 | 53, 54 | 7d |  | start no earlier than 2011-09-30 | CEMENTO PORTLAND TIPO I [2041.12 BLS]; ADITIVO INCORPORADOR DE AIRE [26.81 GLN]; DESMOLDANTE PARA MADERA [4.54 GLN]; IMPRIMANTE PARA SELLANTES JUNTAS [3 GLN]; SELLADOR DE JUNTAS [41.23 GLN]; COMBUSTIBLE [76.2 GLN]; VOLQUETE DE 15 M3 [1075.9%]; CAMION CISTERNA 4X2 3 000 GAL (INC MOTOBOMBA) [88.1%]; VIBRADOR DE 4 HP CAP.=1.25" [1511.8%]; CAPATAZ [2616.4%]; OPERARIO [5329.7%]; OFICIAL [6292.6%]; PEON [31439.1%]; MEZCLADORA DE CONCRETO 11 P3 18 HP [1511.8%]; MOTOBOMBA DIAM 4" [320.3%]; COMPACTADOR TIPO PLANCHA 7 HP [1294.7%]; CARGADOR S/LLANTAS 125-155 HP 3 YD3. [279.8%]; TRACTOR DE ORUGAS DE 190-240 HP [64.7%]; CHANCAD.PRIM.SECUND.5FAJAS 75HP 46-70 T/ [123.1%]; ZARANDA VIBRATORIA 4" x 6" x 14 M.E. 15 HP [169.9%]; LAVADORA DE AGREGADO [145.6%]; GRUPO ELECTROGENO 116 HP 75 KW [46.8%]; GRUPO ELECTROGENO 140HP 90 KW [268.7%]; ALAMBRE NEGRO NACIONAL # 8 [18.16 KG]; CLAVOS [18.16 KG]; CORDON DE RESPALDO PARA EL SELLADO DE JUNTAS 7/8" [90734.7%]; TECNOPOR DE 3/4" [90.71 M2]; MADERA TORNILLO [408.53 P2]; TRIPLAY DE 4´ x 8´ x 18 MM. [9.08 PLN] | 189285h | 3,820,737.59 | 05.25 | 000000000000129 | 2044.7 | 68.45 | 139959.72 |  |
| 53 | 1.5.26 | ZANJA DE CORONACION | 72d | 2012-10-13 | 2012-12-24 | 9SS+180d, 10SS+180d, 11SS+180d | 7d | 0d | start no earlier than 2011-09-30 | CEMENTO PORTLAND TIPO I [2244.48 BLS]; ADITIVO INCORPORADOR DE AIRE [29.48 GLN]; DESMOLDANTE PARA MADERA [98.5 GLN]; IMPRIMANTE PARA SELLANTES JUNTAS [3.34 GLN]; SELLADOR DE JUNTAS [45.31 GLN]; COMBUSTIBLE [83.79 GLN]; VOLQUETE DE 15 M3 [1375.8%]; CAMION CISTERNA 4X2 3 000 GAL (INC MOTOBOMBA) [103.8%]; VIBRADOR DE 4 HP CAP.=1.25" [1662.4%]; CAPATAZ [4748.6%]; OPERARIO [19219.2%]; OFICIAL [20151.8%]; PEON [67266.4%]; MEZCLADORA DE CONCRETO 11 P3 18 HP [1662.4%]; MOTOBOMBA DIAM 4" [352.2%]; COMPACTADOR TIPO PLANCHA 7 HP [1725.2%]; CARGADOR S/LLANTAS 125-155 HP 3 YD3. [342.3%]; TRACTOR DE ORUGAS DE 190-240 HP [71.2%]; CHANCAD.PRIM.SECUND.5FAJAS 75HP 46-70 T/ [135.4%]; ZARANDA VIBRATORIA 4" x 6" x 14 M.E. 15 HP [186.8%]; LAVADORA DE AGREGADO [160.1%]; GRUPO ELECTROGENO 116 HP 75 KW [51.4%]; GRUPO ELECTROGENO 140HP 90 KW [295.5%]; ALAMBRE NEGRO NACIONAL # 8 [394.02 KG]; CLAVOS [394.02 KG]; CORDON DE RESPALDO PARA EL SELLADO DE JUNTAS 7/8" [99722.4%]; TECNOPOR DE 3/4" [99.74 M2]; MADERA TORNILLO [8865.45 P2]; TRIPLAY DE 4´ x 8´ x 18 MM. [197.01 PLN] | 688381h | 11,570,501.01 | 05.26 | 000000000000049 | 1670 | 169.22 | 282597.4 |  |
| 54 | 1.5.27 | CUNETA DE CORONACION | 11d | 2012-12-24 | 2013-01-04 | 53 | 7d | 0d | start no earlier than 2011-09-30 | CEMENTO PORTLAND TIPO I [1044.48 BLS]; ADITIVO INCORPORADOR DE AIRE [13.72 GLN]; DESMOLDANTE PARA MADERA [2.32 GLN]; IMPRIMANTE PARA SELLANTES JUNTAS [1.55 GLN]; SELLADOR DE JUNTAS [21.11 GLN]; COMBUSTIBLE [38.99 GLN]; VOLQUETE DE 15 M3 [505.2%]; CAMION CISTERNA 4X2 3 000 GAL (INC MOTOBOMBA) [30%]; VIBRADOR DE 4 HP CAP.=1.25" [773.6%]; CAPATAZ [1092.7%]; OPERARIO [2727.1%]; OFICIAL [3236.3%]; PEON [12288%]; MEZCLADORA DE CONCRETO 11 P3 18 HP [773.6%]; MOTOBOMBA DIAM 4" [163.9%]; CARGADOR S/LLANTAS 125-155 HP 3 YD3. [135%]; TRACTOR DE ORUGAS DE 190-240 HP [33.1%]; CHANCAD.PRIM.SECUND.5FAJAS 75HP 46-70 T/ [63%]; ZARANDA VIBRATORIA 4" x 6" x 14 M.E. 15 HP [87%]; LAVADORA DE AGREGADO [74.5%]; GRUPO ELECTROGENO 116 HP 75 KW [23.9%]; GRUPO ELECTROGENO 140HP 90 KW [137.5%]; ALAMBRE NEGRO NACIONAL # 8 [9.28 KG]; CLAVOS [9.28 KG]; CORDON DE RESPALDO PARA EL SELLADO DE JUNTAS 7/8" [46401.7%]; TECNOPOR DE 3/4" [46.42 M2]; MADERA TORNILLO [208.9 P2]; TRIPLAY DE 4´ x 8´ x 18 MM. [4.64 PLN] | 19487.2h | 408,311.56 | 05.27 | 000000000000050 | 1135 | 57.32 | 65058.2 |  |
| 55 | 1.5.28 | ZANJA DE DRENAJE | 10d | 2012-11-22 | 2012-12-02 | 13SS+180d | 85d |  | start no earlier than 2011-09-30 | VOLQUETE DE 15 M3 [314.5%]; CAMION CISTERNA 4X2 3 000 GAL (INC MOTOBOMBA) [13.7%]; CAPATAZ [924.1%]; OFICIAL [56.5%]; PEON [10457%]; COMPACTADOR TIPO PLANCHA 7 HP [602.4%]; CARGADOR S/LLANTAS 125-155 HP 3 YD3. [56.5%] | 9939.72h | 194,193.47 | 05.28 | 000000000000136 | 1205 | 16.58 | 19978.9 |  |
| 56 | 1.5.29 | BORDILLO | 8d | 2012-11-05 | 2012-11-13 | 22 | 104d |  | start no earlier than 2011-09-30 | CEMENTO PORTLAND TIPO I [276.57 BLS]; ADITIVO INCORPORADOR DE AIRE [3.63 GLN]; DESMOLDANTE PARA MADERA [6.78 GLN]; IMPRIMANTE PARA SELLANTES JUNTAS [0.1 GLN]; SELLADOR DE JUNTAS [1.34 GLN]; COMBUSTIBLE [8.6 GLN]; VOLQUETE DE 15 M3 [76.2%]; CAMION CISTERNA 4X2 3 000 GAL (INC MOTOBOMBA) [6.6%]; VIBRADOR DE 4 HP CAP.=1.25" [170.7%]; CAPATAZ [288.2%]; OPERARIO [2044.1%]; OFICIAL [2080.5%]; PEON [4079%]; MEZCLADORA DE CONCRETO 11 P3 18 HP [170.7%]; MOTOBOMBA DIAM 4" [36.2%]; CARGADOR S/LLANTAS 125-155 HP 3 YD3. [23.5%]; TRACTOR DE ORUGAS DE 190-240 HP [7.3%]; CHANCAD.PRIM.SECUND.5FAJAS 75HP 46-70 T/ [13.9%]; ZARANDA VIBRATORIA 4" x 6" x 14 M.E. 15 HP [19.2%]; LAVADORA DE AGREGADO [16.4%]; GRUPO ELECTROGENO 116 HP 75 KW [5.3%]; GRUPO ELECTROGENO 140HP 90 KW [30.3%]; ALAMBRE NEGRO NACIONAL # 16 [63.24 KG]; ALAMBRE NEGRO NACIONAL # 8 [27.13 KG]; CLAVOS [27.13 KG]; ACERO CORRUGADO FY=4200 KG/CM2 GRADO 60 [1328.04 KG.]; CORDON DE RESPALDO PARA EL SELLADO DE JUNTAS 7/8" [2951.2%]; TECNOPOR DE 3/4" [3.41 M2]; MADERA TORNILLO [610.43 P2]; TRIPLAY DE 4´ x 8´ x 18 MM. [13.57 PLN] | 5803.59h | 95,366.2 | 05.29 | 000000000000051 | 439 | 60.86 | 26717.54 |  |
| 57 | 1.5.30 | EMBOQUILLADO DE PIEDRA e=0.20m(FC=175 Kg/cm2+60%PM) | 77d | 2012-08-19 | 2012-11-04 | 33SS+10d, 40SS+10d | 113d |  | start no earlier than 2011-09-30 | CEMENTO PORTLAND TIPO I [5509.27 BLS]; ADITIVO INCORPORADOR DE AIRE [72.36 GLN]; COMBUSTIBLE [205.68 GLN]; VOLQUETE DE 15 M3 [17%]; CAMION CISTERNA 4X2 3 000 GAL (INC MOTOBOMBA) [1.7%]; VIBRADOR DE 4 HP CAP.=1.25" [13.3%]; CAPATAZ [50.3%]; OPERARIO [41.2%]; OFICIAL [244.9%]; PEON [760.4%]; MEZCLADORA DE CONCRETO 11 P3 18 HP [13.3%]; MOTOBOMBA DIAM 4" [2.8%]; COMPACTADOR TIPO PLANCHA 7 HP [49.8%]; CARGADOR S/LLANTAS 125-155 HP 3 YD3. [3.3%]; TRACTOR DE ORUGAS DE 190-240 HP [0.6%]; CHANCAD.PRIM.SECUND.5FAJAS 75HP 46-70 T/ [1.1%]; ZARANDA VIBRATORIA 4" x 6" x 14 M.E. 15 HP [1.5%]; LAVADORA DE AGREGADO [1.3%]; GRUPO ELECTROGENO 116 HP 75 KW [0.4%]; GRUPO ELECTROGENO 140HP 90 KW [2.4%] | 7423.76h | 128,659.88 | 05.30 | 000000000000052 | 9182.11 | 69.84 | 641278.56 | 30 |
| 58 | 1.5.31 | EMBOQUILLADO DE PIEDRA e=0.30m(FC=210Kg/cm2+60%PM) | 70d | 2012-08-31 | 2012-11-09 | 31 | 108d |  | start no earlier than 2011-09-30 | CEMENTO PORTLAND TIPO I [2113.66 BLS]; ADITIVO INCORPORADOR DE AIRE [27.76 GLN]; COMBUSTIBLE [65.76 GLN]; VOLQUETE DE 15 M3 [23.8%]; CAMION CISTERNA 4X2 3 000 GAL (INC MOTOBOMBA) [1.8%]; VIBRADOR DE 4 HP CAP.=1.25" [18.6%]; CAPATAZ [57.9%]; OPERARIO [57.7%]; OFICIAL [263.5%]; PEON [892.6%]; MEZCLADORA DE CONCRETO 11 P3 18 HP [18.6%]; MOTOBOMBA DIAM 4" [3.9%]; COMPACTADOR TIPO PLANCHA 7 HP [46.6%]; CARGADOR S/LLANTAS 125-155 HP 3 YD3. [4.6%]; TRACTOR DE ORUGAS DE 190-240 HP [0.8%]; CHANCAD.PRIM.SECUND.5FAJAS 75HP 46-70 T/ [1.5%]; ZARANDA VIBRATORIA 4" x 6" x 14 M.E. 15 HP [2.1%]; LAVADORA DE AGREGADO [1.8%]; GRUPO ELECTROGENO 116 HP 75 KW [0.6%]; GRUPO ELECTROGENO 140HP 90 KW [3.3%] | 7839.38h | 141,961.1 | 05.31 | 000000000000137 | 1957.09 | 96.64 | 189133.18 | 28 |
| 59 | 1.5.32 | GEOTEXTIL NO TEJIDO TIPO 2 | 63d | 2012-07-05 | 2012-09-06 | 43SS | 172d |  | start no earlier than 2011-09-30 | CAPATAZ [9.9%]; OPERARIO [99%]; PEON [99%]; GEOTEXTIL NO TEJIDO TIPO 2 [27433.1 M2] | 1047.45h | 14,055.83 | 05.32 | 000000000000054 | 24939.18 | 4.01 | 100006.11 | 400 |
| 60 | 1.5.33 | JUNTA PARA MUROS | 8d | 2012-08-20 | 2012-08-28 | 33FF | 181d |  | start no earlier than 2011-09-30 | IMPRIMANTE PARA SELLANTES JUNTAS [3.82 GLN]; SELLADOR DE JUNTAS [47.58 GLN]; CAPATAZ [9.6%]; OFICIAL [96.2%]; PEON [96.2%]; CORDON DE RESPALDO PARA EL SELLADO DE JUNTAS 1 1/8" [114180%]; TECNOPOR DE 1" [307.97 M2] | 129.35h | 2,006.51 | 05.33 | 000000000000055 | 307.97 | 40.91 | 12599.05 | 40 |
| 61 | 1.5.34 | JUNTA DE ALCANTARILLA MARCO | 2d | 2012-10-07 | 2012-10-09 | 31FF, 32FF | 139d |  | start no earlier than 2011-09-30 | IMPRIMANTE PARA SELLANTES JUNTAS [0.78 GLN]; SELLADOR DE JUNTAS [10.8 GLN]; CAPATAZ [9.9%]; OFICIAL [99%]; PEON [99%]; CORDON DE RESPALDO PARA EL SELLADO DE JUNTAS 7/8" [23740%]; TECNOPOR DE 3/4" [75.97 M2] | 33.26h | 804.93 | 05.34 | 000000000000195 | 237.4 | 11.6 | 2753.84 | 120 |
| 62 | 1.5.35 | JUNTA DE BADEN | 6d | 2012-08-25 | 2012-08-31 | 31FF | 178d |  | start no earlier than 2011-09-30 | IMPRIMANTE PARA SELLANTES JUNTAS [3.2 GLN]; SELLADOR DE JUNTAS [53.05 GLN]; CAPATAZ [9.9%]; OPERARIO [99.5%]; PEON [99.5%]; CORTADORA DE PAVIMENTO CON DISCO [99.5%]; BARRA LISA 3/4" [188378%]; TUBO DE F°G° 7/8" [78491.4%] | 148.03h | 1,940.9 | 05.35 | 000000000000056 | 477.5 | 67.59 | 32274.23 | 80 |
| 63 | 1.5.36 | GAVION CAJA (Zn-5Al-MM) | 75d | 2012-04-22 | 2012-07-06 | 13FF | 234d |  | start no earlier than 2011-09-30 | VOLQUETE DE 15 M3 [8.2%]; COMPRESORA NEUMATICA 250-330 PCM 87 HP [1.7%]; CAPATAZ [10.5%]; OFICIAL [102.7%]; PEON [1188.6%]; CARGADOR S/LLANTAS 125-155 HP 3 YD3. [3.2%]; EXCAVADORA SOBRE LLANTAS 58 HP 1. YD3 [5.8%]; MARTILLO NEUMATICO DE 29 Kg. [3.5%]; MOTOBOMBA 34 HP 8" [5.8%]; BARRENO 5' X 7/8" [0.09 und]; GAVION CAJA 5.0 X 1.0 X 1.0 m [141.02 und]; GAVION CAJA 5.0 X 1.5 X 1.0 m [47.01 und]; GAVION COLCHON RENO 5.0 X 2.0 X 0.3 m [47.01 und]; GAVION CAJA 5.0 X 1.0 X 0.50 m [47.01 und]; GAVION CAJA 5.0 X 1.5 X 0.50 m [47.01 und] | 7979.4h | 115,439.57 | 05.36 | 000000000000178 | 1492.25 | 160.6 | 239655.35 | 20 |
| 64 | 1.5.37 | ESTABILIZACION DEL TALUD | 13d | 2012-09-07 | 2012-09-20 | 11FF | 158d |  | start no earlier than 2011-09-30 | CEMENTO PORTLAND TIPO I [122.19 BLS]; ADITIVO INCORPORADOR DE AIRE [1.6 GLN]; COMBUSTIBLE [3.8 GLN]; VOLQUETE DE 15 M3 [2%]; CAMION CISTERNA 4X2 3 000 GAL (INC MOTOBOMBA) [0.2%]; VIBRADOR DE 4 HP CAP.=1.25" [5.8%]; CAPATAZ [55.2%]; OPERARIO [117.4%]; OFICIAL [317.5%]; PEON [261%]; MEZCLADORA DE CONCRETO 11 P3 18 HP [5.8%]; MOTOBOMBA DIAM 4" [1.2%]; CARGADOR S/LLANTAS 125-155 HP 3 YD3. [0.7%]; TRACTOR DE ORUGAS DE 190-240 HP [0.2%]; CHANCAD.PRIM.SECUND.5FAJAS 75HP 46-70 T/ [0.5%]; ZARANDA VIBRATORIA 4" x 6" x 14 M.E. 15 HP [0.7%]; LAVADORA DE AGREGADO [0.6%]; GRUPO ELECTROGENO 116 HP 75 KW [0.2%]; GRUPO ELECTROGENO 140HP 90 KW [1%]; ACERO CORRUGADO FY=4200 KG/CM2 GRADO 60 [477.89 KG.]; MALLA DE ALTA RESISTENCIA [1318.86 M2] | 800.79h | 11,545.12 | 05.37 | 000000000000179 | 1293 | 64.08 | 82855.44 | 100 |
| 65 | 1.5.38 | PINTURA BITUMINOSA | 13d | 2012-08-31 | 2012-09-13 | 31 | 165d |  | start no earlier than 2011-09-30 | PINTURA BITUMINOSA [170.22 GLN]; IMPRIMANTE P/EPOXICO [35.66 GLN]; DISOLVENTE DE PINTURA [30.19 GLN]; CAPATAZ [19.1%]; OPERARIO [191.1%]; OFICIAL [95.6%]; PEON [191.1%] | 516.86h | 7,364.02 | 05.38 | 000000000000198 | 1242.46 | 29.5 | 36652.57 | 100 |
| 66 | 1.5.39 | GEOCOMPUESTO DE DRENAJE TRIDIMENSIONAL | 3d | 2012-08-31 | 2012-09-03 | 31 | 175d |  | start no earlier than 2011-09-30 | CAPATAZ [7.7%]; OPERARIO [77.4%]; PEON [77.4%]; GEOCOMPUESTO DE DRENAJE [1021.14 M2] | 38.99h | 541.31 | 05.39 | 000000000000199 | 928.31 | 20.65 | 19169.6 | 400 |

| ID | WBS | Task | Duration | Start | Finish | Predecessors | Total slack | Free slack | Constraint | Resources | Work | Cost | Text1 | Text8 | Text2 | Text3 | Text4 | Text6 |
| --- | --- | --- | --- | --- | --- | --- | --- | --- | --- | --- | --- | --- | --- | --- | --- | --- | --- | --- |
| 67 | 1.6 | **TRANSPORTE** | 253d | 2012-04-16 | 2012-12-25 |  | 62d |  |  |  | 5271510h | 1,201,381,283.39 | 06 | 000000000000057 |  |  |  |  |
| 68 | 1.6.1 | TRANSPORTE DE MATERIALES GRANULARES ENTRE 120 M Y 1000 M | 162d | 2012-06-24 | 2012-12-03 | 18SS | 84d | 0d | start no earlier than 2011-09-30 | VOLQUETE DE 15 M3; OFICIAL [38.8%]; CARGADOR SOBRE LLANTAS 200-250 HP 4 - 4.1 YD3 [38.8%] | 2301.06h | 438,875.24 | 06.01 | 000000000000058 | 108976.85 | 8.03 | 875084.11 | 338 |
| 69 | 1.6.2 | TRANSPORTE DE MATERIALES GRANULARES PARA DISTANCIAS MAYORES DE 1000 M | 162d | 2012-06-24 | 2012-12-03 | 68SS | 84d |  | start no earlier than 2011-09-30 | VOLQUETE DE 15 M3 [158588%] | 2055295h | 503,876,020.02 | 06.02 | 000000000000059 | 1585875.45 | 1.96 | 3108315.88 | 1000 |
| 70 | 1.6.3 | TRANSPORTE DE ESCOMBROS ENTRE 120 M Y 1000 METROS | 108d | 2012-04-16 | 2012-08-02 | 9SS, 10SS, 11SS | 72d | 0d | start no earlier than 2011-09-30 | VOLQUETE DE 15 M3 [107852%]; OFICIAL [42129.8%]; CARGADOR SOBRE LLANTAS 200-250 HP 4 - 4.1 YD3 [42129.8%] | 1659847h | 316,258,931.82 | 06.03 | 000000000000062 | 337038.44 | 8.69 | 2928864.04 | 312 |
| 71 | 1.6.4 | TRANSPORTE DE ESCOMBROS PARA DISTANCIAS MAYORES DE 1000 M | 108d | 2012-04-16 | 2012-08-02 | 70SS | 72d | 0d | start no earlier than 2011-09-30 | VOLQUETE DE 15 M3 [179587%] | 1551633h | 380,398,327.16 | 06.04 | 000000000000063 | 1651376.03 | 2.13 | 3517430.94 | 923 |
| 72 | 1.6.5 | TRANSPORTE DE MEZCLA ASFALTICA HASTA 1 KM | 102d | 2012-09-14 | 2012-12-25 | 22SS | 62d | 0d | start no earlier than 2011-09-30 | VOLQUETE DE 15 M3 [99%]; OFICIAL [99%] | 1615.24h | 208,366.06 | 06.05 | 000000000000060 | 17480.96 | 11.92 | 208373.04 | 173 |
| 73 | 1.6.6 | TRANSPORTE DE MEZCLA ASFALTICA A MAS DE 1 KM | 102d | 2012-09-14 | 2012-12-25 | 72SS | 62d |  | start no earlier than 2011-09-30 | VOLQUETE DE 15 M3 | 818.91h | 200,763.1 | 06.06 | 000000000000061 | 267301.64 | 2.08 | 555987.41 | 946 |
| 74 | 1.7 | **SEÑALIZACION Y SEGURIDAD VIAL** | 115d | 2012-09-21 | 2013-01-14 |  | 42d |  |  |  | 887608h | 11,583,626.13 | 07 | 000000000000065 |  |  |  |  |
| 75 | 1.7.1 | SEÑAL PREVENTIVA (0.75 M X 0.75 M) | 32d | 2012-10-29 | 2012-11-30 | 78SS+15d | 47d | 5d | start no earlier than 2011-09-30 | TINTA SERIGRAFICA NEGRA [0.94 GLN]; IMPRIMANTE P/EPOXICO [6.08 GLN]; PINTURA EPÓXICO [8.55 GLN]; DISOLVENTE DE PINTURA [2.59 GLN]; MOTOSOLDADORA 250 A [49.6%]; CAPATAZ [23.8%]; OPERARIO [99.2%]; OFICIAL [138.9%]; PEON [39.7%]; CAMIONETA PICK UP 4X2 PICK UP CABINA SIMPLE 84 HP [39.7%]; SOLDADURA E6011 [22.5 KG]; PLATINA DE ACERO DE 2" X 1/8" [67500%]; FIBRA DE VIDRIO DE 4 MM. ACABADO [210.94 M2.]; LAMINA REFLECTORIZANTE ALTA INTENSIDAD [2270.51 P2]; PERNOS 3/8" X 8" [750 und] | 1000.61h | 26,533.72 | 07.01 | 000000000000066 | 375 | 316.05 | 118518.75 |  |
| 76 | 1.7.2 | SEÑAL REGLAMENTARIA 0.80 X 1.20 M. | 6d | 2012-11-03 | 2012-11-09 | 78FF | 42d | 0d | start no earlier than 2011-09-30 | TINTA SERIGRAFICA NEGRA [0.08 GLN]; TINTA SERIGRAFICA ROJA [0.08 GLN]; IMPRIMANTE P/EPOXICO [0.99 GLN]; PINTURA EPÓXICO [1.4 GLN]; DISOLVENTE DE PINTURA [0.42 GLN]; MOTOSOLDADORA 250 A [50%]; CAPATAZ [24%]; OPERARIO; OFICIAL [140%]; PEON [40%]; CAMIONETA PICK UP 4X2 PICK UP CABINA SIMPLE 84 HP [40%]; SOLDADURA E6011 [2.16 KG]; PLATINA DE ACERO DE 2" X 1/8" [6480%]; FIBRA DE VIDRIO DE 4 MM. ACABADO [34.56 M2.]; LAMINA REFLECTORIZANTE ALTA INTENSIDAD [372 P2]; PERNOS 3/8" X 8" [72 und] | 189.12h | 7,624.03 | 07.02 | 000000000000067 | 36 | 437.63 | 15754.68 |  |
| 77 | 1.7.3 | SEÑAL INFORMATIVA | 5d | 2012-11-24 | 2012-11-29 | 79, 80 | 84d | 0d | start no earlier than 2011-09-30 | IMPRIMANTE P/EPOXICO [0.78 GLN]; PINTURA EPÓXICO [1.09 GLN]; DISOLVENTE DE PINTURA [0.33 GLN]; MOTOSOLDADORA 250 A [45%]; CAPATAZ [22.3%]; OPERARIO [89.9%]; OFICIAL [133%]; PEON [86.3%]; CAMIONETA PICK UP 4X2 PICK UP CABINA SIMPLE 84 HP [43.2%]; CAMION GRUA DE 6 TON [43.2%]; SOLDADURA E6011 [0.78 KG]; PERFIL 1 1/2" x 1 1/2" x 3/16" [7125.5%]; FIBRA DE VIDRIO DE 4 MM. ACABADO [26.97 M2.]; LAMINA REFLECTORIZANTE ALTA INTENSIDAD [290.31 P2] | 185.12h | 6,816.7 | 07.03 | 000000000000068 | 26.97 | 551.99 | 14887.17 |  |
| 78 | 1.7.4 | POSTES DE SOPORTE DE SEÑALES | 26d | 2012-10-14 | 2012-11-09 | 22SS+30d | 42d | 0d | start no earlier than 2011-09-30 | CEMENTO PORTLAND TIPO I [542.23 BLS]; ADITIVO INCORPORADOR DE AIRE [7.13 GLN]; DESMOLDANTE PARA MADERA [48.11 GLN]; COMBUSTIBLE [23.02 GLN]; PINTURA ESMALTE SINTETICO [16.4 GLN]; IMPRIMANTE P/ MUROS [13.55 GLN]; THINNER STANDARD [2.71 GLN]; DISOLVENTE P / IMPRIMANTE MURO/P.TRAFICO [1.85 GLN]; VOLQUETE DE 15 M3 [3%]; CAMION CISTERNA 4X2 3 000 GAL (INC MOTOBOMBA) [0.3%]; VIBRADOR DE 4 HP CAP.=1.25" [8.8%]; CAPATAZ [26.6%]; OPERARIO [332.6%]; OFICIAL [186.7%]; PEON [601.9%]; MEZCLADORA DE CONCRETO 11 P3 18 HP [8.8%]; MOTOBOMBA DIAM 4" [1.9%]; CARGADOR S/LLANTAS 125-155 HP 3 YD3. [1%]; TRACTOR DE ORUGAS DE 190-240 HP [0.4%]; CHANCAD.PRIM.SECUND.5FAJAS 75HP 46-70 T/ [0.7%]; ZARANDA VIBRATORIA 4" x 6" x 14 M.E. 15 HP [1%]; LAVADORA DE AGREGADO [0.8%]; GRUPO ELECTROGENO 116 HP 75 KW [0.3%]; GRUPO ELECTROGENO 140HP 90 KW [1.6%]; ALAMBRE NEGRO NACIONAL # 16 [166.64 KG]; ALAMBRE NEGRO NACIONAL # 8 [192.43 KG]; CLAVOS [192.43 KG]; ACERO CORRUGADO FY=4200 KG/CM2 GRADO 60 [3499.44 KG.]; MADERA TORNILLO [4329.68 P2]; TRIPLAY DE 4´ x 8´ x 18 MM. [96.22 PLN] | 2446.7h | 34,687.17 | 07.04 | 000000000000069 | 411 | 305.13 | 125408.43 |  |
| 79 | 1.7.5 | ESTRUCTURA DE SOPORTE DE SEÑALES TIPO E-1 | 3d | 2012-11-09 | 2012-11-12 | 78 | 84d | 0d | start no earlier than 2011-09-30 | CEMENTO PORTLAND TIPO I [23.62 BLS]; ADITIVO INCORPORADOR DE AIRE [0.31 GLN]; DESMOLDANTE PARA MADERA [0.14 GLN]; COMBUSTIBLE [0.88 GLN]; PINTURA ESMALTE SINTETICO [0.15 GLN]; PINTURA ZINCROMATO [0.09 GLN]; THINNER STANDARD [0.16 GLN]; VOLQUETE DE 15 M3 [2.9%]; CAMION CISTERNA 4X2 3 000 GAL (INC MOTOBOMBA) [0.2%]; MOTOSOLDADORA 250 A [50%]; VIBRADOR DE 4 HP CAP.=1.25" [5.8%]; CAPATAZ [56.6%]; OPERARIO [129.4%]; OFICIAL [130.8%]; PEON [381.1%]; MEZCLADORA DE CONCRETO 11 P3 18 HP [5.8%]; MOTOBOMBA DIAM 4" [1.2%]; COMPACTADOR TIPO PLANCHA 7 HP [0.3%]; CARGADOR S/LLANTAS 125-155 HP 3 YD3. [0.8%]; TRACTOR DE ORUGAS DE 190-240 HP [0.2%]; RODILLO LISO VIBRATORIO MANUAL 10.8 HP 0.8-1.1 TON [0.1%]; CHANCAD.PRIM.SECUND.5FAJAS 75HP 46-70 T/ [0.5%]; ZARANDA VIBRATORIA 4" x 6" x 14 M.E. 15 HP [0.7%]; LAVADORA DE AGREGADO [0.6%]; GRUPO ELECTROGENO 116 HP 75 KW [0.2%]; GRUPO ELECTROGENO 140HP 90 KW [1%]; ALAMBRE NEGRO NACIONAL # 16 [1.67 KG]; ALAMBRE NEGRO NACIONAL # 8 [0.58 KG]; CLAVOS [0.58 KG]; SOLDADURA E6011 [3.9 KG]; ACERO CORRUGADO FY=4200 KG/CM2 GRADO 60 [34.98 KG.]; PLATINA DE ACERO DE 1" X 1/4" [816%]; PLATINA DE ACERO DE 3" X 3/16" [213.4%]; PLATINA DE ACERO DE 2" X 3/16" [45.7%]; PLATINA DE ACERO DE 1" X 3/16" [365.8%]; TUBO DE FIERRO 3" [1520%]; TUBO DE FIERRO 2" [1560%]; MADERA TORNILLO [12.96 P2]; TRIPLAY DE 4´ x 8´ x 18 MM. [0.29 PLN]; PERNOS 5/8" X 14" [24 und]; PERNOS 3/8" X 3" [24 und]; PLANCHA DE ACERO 16 MM X 1.22 M X 2.40 M [0.08 und]; PLANCHA DE ACERO 9.5 MM X 1.22 M X 2.40 M [0.05 und] | 184.4h | 5,422.45 | 07.05 | 000000000000070 |  | 800.77 | 4804.62 |  |
| 80 | 1.7.6 | ESTRUCTURA DE SOPORTE DE SEÑALES TIPO E-2 | 12d | 2012-11-12 | 2012-11-24 | 79 | 84d | 0d | start no earlier than 2011-09-30 | CEMENTO PORTLAND TIPO I [94.5 BLS]; ADITIVO INCORPORADOR DE AIRE [1.24 GLN]; DESMOLDANTE PARA MADERA [0.58 GLN]; COMBUSTIBLE [3.53 GLN]; PINTURA ESMALTE SINTETICO [0.53 GLN]; PINTURA ZINCROMATO [0.34 GLN]; THINNER STANDARD [0.59 GLN]; VOLQUETE DE 15 M3 [2.9%]; CAMION CISTERNA 4X2 3 000 GAL (INC MOTOBOMBA) [0.2%]; MOTOSOLDADORA 250 A [50%]; VIBRADOR DE 4 HP CAP.=1.25" [5.8%]; CAPATAZ [56.6%]; OPERARIO [129.4%]; OFICIAL [130.8%]; PEON [381.1%]; MEZCLADORA DE CONCRETO 11 P3 18 HP [5.8%]; MOTOBOMBA DIAM 4" [1.2%]; COMPACTADOR TIPO PLANCHA 7 HP [0.3%]; CARGADOR S/LLANTAS 125-155 HP 3 YD3. [0.8%]; TRACTOR DE ORUGAS DE 190-240 HP [0.2%]; RODILLO LISO VIBRATORIO MANUAL 10.8 HP 0.8-1.1 TON [0.1%]; CHANCAD.PRIM.SECUND.5FAJAS 75HP 46-70 T/ [0.5%]; ZARANDA VIBRATORIA 4" x 6" x 14 M.E. 15 HP [0.7%]; LAVADORA DE AGREGADO [0.6%]; GRUPO ELECTROGENO 116 HP 75 KW [0.2%]; GRUPO ELECTROGENO 140HP 90 KW [1%]; ALAMBRE NEGRO NACIONAL # 16 [6.66 KG]; ALAMBRE NEGRO NACIONAL # 8 [2.3 KG]; CLAVOS [2.3 KG]; SOLDADURA E6011 [7.8 KG]; ACERO CORRUGADO FY=4200 KG/CM2 GRADO 60 [139.91 KG.]; PLATINA DE ACERO DE 1" X 1/4" [3264%]; PLATINA DE ACERO DE 3" X 3/16" [640.1%]; PLATINA DE ACERO DE 2" X 3/16" [182.9%]; PLATINA DE ACERO DE 1" X 3/16" [1401.8%]; TUBO DE FIERRO 3" [9687.6%]; MADERA TORNILLO [51.84 P2]; TRIPLAY DE 4´ x 8´ x 18 MM. [1.15 PLN]; PERNOS 5/8" X 14" [96 und]; PERNOS 3/8" X 3" [72 und]; PLANCHA DE ACERO 16 MM X 1.22 M X 2.40 M [0.34 und]; PLANCHA DE ACERO 9.5 MM X 1.22 M X 2.40 M [0.21 und] | 737.58h | 14,608.63 | 07.06 | 000000000000071 | 12 | 1591.02 | 19092.24 |  |
| 81 | 1.7.7 | POSTES DELINEADORES | 38d | 2012-09-28 | 2012-11-05 | 22FF | 83d | 0d | start no earlier than 2011-09-30 | CEMENTO PORTLAND TIPO I [624.44 BLS]; ADITIVO INCORPORADOR DE AIRE [8.21 GLN]; DESMOLDANTE PARA MADERA [25.86 GLN]; COMBUSTIBLE [27.27 GLN]; PINTURA ESMALTE SINTETICO [12.12 GLN]; IMPRIMANTE P/ MUROS [9.6 GLN]; THINNER STANDARD [1.96 GLN]; DISOLVENTE P / IMPRIMANTE MURO/P.TRAFICO [1.4 GLN]; VOLQUETE DE 15 M3 [6.7%]; CAMION CISTERNA 4X2 3 000 GAL (INC MOTOBOMBA) [0.6%]; VIBRADOR DE 4 HP CAP.=1.25" [14.2%]; CAPATAZ [46%]; OPERARIO [363.9%]; OFICIAL [260.6%]; PEON [782.4%]; MEZCLADORA DE CONCRETO 11 P3 18 HP [14.2%]; MOTOBOMBA DIAM 4" [3%]; CARGADOR S/LLANTAS 125-155 HP 3 YD3. [1.9%]; TRACTOR DE ORUGAS DE 190-240 HP [0.6%]; CHANCAD.PRIM.SECUND.5FAJAS 75HP 46-70 T/ [1.2%]; ZARANDA VIBRATORIA 4" x 6" x 14 M.E. 15 HP [1.6%]; LAVADORA DE AGREGADO [1.4%]; GRUPO ELECTROGENO 116 HP 75 KW [0.4%]; GRUPO ELECTROGENO 140HP 90 KW [2.5%]; ALAMBRE NEGRO NACIONAL # 16 [86.33 KG]; ALAMBRE NEGRO NACIONAL # 8 [103.45 KG]; CLAVOS [103.45 KG]; PEGAMENTO EPOXICO [11.18 KG]; ACERO CORRUGADO FY=4200 KG/CM2 GRADO 60 [1812.86 KG.]; PLANCHA DE ACERO 1.5 MM X 1.22 M X 2.40 M [9.69 M2]; LAMINA REFLECTORIZANTE ALTA INTENSIDAD [301.04 P2]; MADERA TORNILLO [2327.67 P2]; TRIPLAY DE 4´ x 8´ x 18 MM. [51.73 PLN] | 4563.68h | 67,114.71 | 07.07 | 000000000000072 | 932 | 117.78 | 109770.96 | 25 |
| 82 | 1.7.8 | TACHA RETROREFLECTIVA | 59d | 2012-09-21 | 2012-11-19 | 22SS+7d | 98d |  | start no earlier than 2011-09-30 | CAPATAZ [11620.8%]; OPERARIO [58104%]; PEON [116208%]; PEGAMENTO EPOXICO [290.52 KG]; TACHA [29052 und] | 877603h | 11,408,333.36 | 07.08 | 000000000000073 | 29052 | 13.54 | 393364.08 | 50 |
| 83 | 1.7.9 | MARCAS EN EL PAVIMENTO | 11d | 2012-11-05 | 2012-11-16 | 22 | 101d |  | start no earlier than 2011-09-30 | DISOLVENTE P / IMPRIMANTE MURO/P.TRAFICO [104.39 GLN]; PINTURA DE TRAFICO [833.29 GLN]; CAPATAZ [48.9%]; OPERARIO [97.8%]; PEON [391.3%]; MAQUINA PARA PINTAR PAVIMENTOS [97.8%]; MICROESFERAS DE VIDRIO [3204.95 KG] | 559.49h | 9,624.5 | 07.09 | 000000000000074 | 9157 | 6.64 | 60802.48 | 850 |
| 84 | 1.7.10 | BARRERA DE SEGURIDAD METALICO P3 | 72d | 2012-11-03 | 2013-01-14 | 75SS, 76SS | 42d |  | start no earlier than 2011-09-30 | BARRERA DE SEGURIDAD H2 BL W3 ASI 3 ONDAS(INC. POSTES) [108000%]; INSTALACION DE BARRERA DE SEGURIDAD; TERMINAL TIPO COLA DE PEZ [56.05 und] |  | 451.7 | 07.10 | 000000000000075 | 1080 | 290.79 | 314053.2 | 15 |
| 85 | 1.7.11 | POSTE DE KILOMETRAJE | 29d | 2012-11-05 | 2012-12-04 | 81 | 83d |  | start no earlier than 2011-09-30 | CEMENTO PORTLAND TIPO I [20.89 BLS]; ADITIVO INCORPORADOR DE AIRE [0.27 GLN]; DESMOLDANTE PARA MADERA [1.11 GLN]; COMBUSTIBLE [0.89 GLN]; PINTURA ESMALTE SINTETICO [0.42 GLN]; IMPRIMANTE P/ MUROS [0.34 GLN]; THINNER STANDARD [0.07 GLN]; DISOLVENTE P / IMPRIMANTE MURO/P.TRAFICO [0.05 GLN]; VOLQUETE DE 15 M3 [0.3%]; CAMION CISTERNA 4X2 3 000 GAL (INC MOTOBOMBA) [0%]; VIBRADOR DE 4 HP CAP.=1.25" [0.6%]; CAPATAZ [1.7%]; OPERARIO [16.6%]; OFICIAL [8.4%]; PEON [30.9%]; MEZCLADORA DE CONCRETO 11 P3 18 HP [0.6%]; MOTOBOMBA DIAM 4" [0.1%]; CARGADOR S/LLANTAS 125-155 HP 3 YD3. [0.1%]; TRACTOR DE ORUGAS DE 190-240 HP [0%]; CHANCAD.PRIM.SECUND.5FAJAS 75HP 46-70 T/ [0%]; ZARANDA VIBRATORIA 4" x 6" x 14 M.E. 15 HP [0.1%]; LAVADORA DE AGREGADO [0.1%]; GRUPO ELECTROGENO 116 HP 75 KW [0%]; GRUPO ELECTROGENO 140HP 90 KW [0.1%]; ALAMBRE NEGRO NACIONAL # 16 [3.24 KG]; ALAMBRE NEGRO NACIONAL # 8 [4.43 KG]; CLAVOS [4.43 KG]; ACERO CORRUGADO FY=4200 KG/CM2 GRADO 60 [68.09 KG.]; MADERA TORNILLO [99.72 P2]; TRIPLAY DE 4´ x 8´ x 18 MM. [2.22 PLN] | 138.15h | 2,409.17 | 07.11 | 000000000000076 | 29 | 120.54 | 3495.66 |  |
| 86 | 1.8 | **PROTECCION AMBIENTAL** | 325d | 2012-04-01 | 2013-02-20 |  | 5d |  |  |  | 1134484h | 122,300,686.69 | 08 | 000000000000077 |  |  |  |  |
| 87 | 1.8.1 | REVEGETACIÓN | 31d | 2012-11-14 | 2012-12-15 | 88 | 72d |  | start no earlier than 2011-09-30 | CAMION CISTERNA 4X2 3 000 GAL (INC MOTOBOMBA) [4.9%]; OFICIAL [97.4%]; PEON [979.1%]; PLANTAS NATIVAS [18.12 KG] | 2682.07h | 33,355.44 | 08.01 | 000000000000078 | 6.04 | 5814.94 | 35122.24 | 0.2 |
| 88 | 1.8.2 | DEPOSITO DE DESECHOS | 82d | 2012-08-24 | 2012-11-14 | 70SS+130d, 71SS+130d | 72d | 0d | start no earlier than 2011-09-30 | CAPATAZ [8193.3%]; PEON [81932.9%]; RODILLO LISO VIBR AUTOP 70-100 HP 7-9 T. [40966.5%]; TRACTOR DE ORUGAS DE 190-240 HP [40966.5%] | 1128708h | 122,026,257.6 | 08.02 | 000000000000079 | 409664.71 | 3.64 | 1491179.54 | 500 |
| 89 | 1.8.3 | READECUACION AMBIENTAL DE CANTERAS DE RIO | 47d | 2012-11-05 | 2012-12-22 | 18, 22 | 56d | 0d | start no earlier than 2011-09-30 | CAMION CISTERNA 4X2 3 000 GAL (INC MOTOBOMBA) [85.4%]; PEON [481.4%]; TRACTOR DE ORUGAS DE 190-240 HP [101.1%] | 2511.15h | 204,168.59 | 08.03 | 000000000000080 | 158412 | 1.3 | 205935.6 | 3400 |
| 90 | 1.8.4 | READECUACION AMBIENTAL DE PLANTAS DE TRITURACION Y DE ASFALTO | 7d | 2012-12-22 | 2012-12-29 | 22, 89 | 56d | 0d | start no earlier than 2011-09-30 | CAPATAZ [89.3%]; PEON [178.6%]; TRACTOR DE ORUGAS DE 190-240 HP [89.3%] | 200h | 18,855.5 | 08.04 | 000000000000170 | 12500 | 1.51 | 18875 | 2000 |
| 91 | 1.8.5 | READECUACION AMBIENTAL DE CAMPAMENTO | 2d | 2012-12-29 | 2012-12-31 | 90 | 56d |  | start no earlier than 2011-09-30 | CAMION CISTERNA 4X2 3 000 GAL (INC MOTOBOMBA) [79.1%]; PEON [454.1%]; TRACTOR DE ORUGAS DE 190-240 HP [62.5%] | 95.33h | 6,392.21 | 08.05 | 000000000000083 | 5000 | 1.29 | 6450 | 4000 |
| 92 | 1.8.6 | READECUACION AMBIENTAL DE PATIO DE MAQUINAS | 2d | 2012-12-22 | 2012-12-24 | 22, 90SS | 63d |  | start no earlier than 2011-09-30 | CAMION CISTERNA 4X2 3 000 GAL (INC MOTOBOMBA) [79.1%]; PEON [454.1%]; TRACTOR DE ORUGAS DE 190-240 HP [62.5%] | 95.33h | 6,392.21 | 08.06 | 000000000000171 | 5000 | 1.29 | 6450 | 4000 |
| 93 | 1.8.7 | MONITOREO DE LA CALIDAD DEL AGUA | 325d | 2012-04-01 | 2013-02-20 | 3SS | 5d | 0d | start no earlier than 2011-09-30 | MONITOREO DE LA CALIDAD DEL AGUA [1 PTO] |  | 381.3 | 08.07 | 000000000000085 |  | 381.3 | 3050.4 |  |
| 94 | 1.8.8 | MONITOREO DE LA CALIDAD DEL AIRE | 325d | 2012-04-01 | 2013-02-20 | 93SS | 5d |  | start no earlier than 2011-09-30 | MONITOREO DE LA CALIDAD DEL AIRE [1 PTO] |  | 1,071 | 08.08 | 000000000000086 | 32 | 1071 | 34272 |  |
| 95 | 1.8.9 | MONITOREO DE RUIDOS | 325d | 2012-04-01 | 2013-02-20 | 93SS | 5d |  | start no earlier than 2011-09-30 | MONITOREO DE RUIDOS [1 PTO] |  | 21 | 08.09 | 000000000000087 | 16 | 21 | 336 |  |
| 96 | 1.8.10 | SEÑAL AMBIENTAL TEMPORAL | 2d | 2012-04-06 | 2012-04-08 | 5SS | 323d |  | start no earlier than 2011-09-30 | CEMENTO PORTLAND TIPO I [8.33 BLS]; ADITIVO INCORPORADOR DE AIRE [0.11 GLN]; COMBUSTIBLE [0.38 GLN]; PINTURA ESMALTE SINTETICO [0.46 GLN]; THINNER STANDARD [0.08 GLN]; VOLQUETE DE 15 M3 [1.9%]; CAMION CISTERNA 4X2 3 000 GAL (INC MOTOBOMBA) [0.1%]; VIBRADOR DE 4 HP CAP.=1.25" [3.7%]; CAPATAZ [20.8%]; OPERARIO [94.9%]; OFICIAL [95.7%]; PEON [162.1%]; MEZCLADORA DE CONCRETO 11 P3 18 HP [3.7%]; MOTOBOMBA DIAM 4" [0.8%]; CARGADOR S/LLANTAS 125-155 HP 3 YD3. [0.5%]; TRACTOR DE ORUGAS DE 190-240 HP [0.2%]; CHANCAD.PRIM.SECUND.5FAJAS 75HP 46-70 T/ [0.3%]; ZARANDA VIBRATORIA 4" x 6" x 14 M.E. 15 HP [0.4%]; LAVADORA DE AGREGADO [0.4%]; GRUPO ELECTROGENO 116 HP 75 KW [0.1%]; GRUPO ELECTROGENO 140HP 90 KW [0.7%]; CLAVOS [2.2 KG]; MADERA TORNILLO [313.6 P2]; TRIPLAY DE 4´ x 8´ x 18 MM. [10 PLN] | 61.81h | 1,149.25 | 08.10 | 000000000000088 | 10 | 324.85 | 3248.5 |  |
| 97 | 1.8.11 | SEÑAL AMBIENTAL PERMANENTE | 4d | 2012-11-29 | 2012-12-03 | 77 | 84d |  | start no earlier than 2011-09-30 | CEMENTO PORTLAND TIPO I [17.5 BLS]; ADITIVO INCORPORADOR DE AIRE [0.23 GLN]; COMBUSTIBLE [0.79 GLN]; PINTURA ESMALTE SINTETICO [0.96 GLN]; THINNER STANDARD [0.16 GLN]; VOLQUETE DE 15 M3 [2%]; CAMION CISTERNA 4X2 3 000 GAL (INC MOTOBOMBA) [0.2%]; VIBRADOR DE 4 HP CAP.=1.25" [3.9%]; CAPATAZ [21.8%]; OPERARIO; OFICIAL; PEON [170.2%]; MEZCLADORA DE CONCRETO 11 P3 18 HP [3.9%]; MOTOBOMBA DIAM 4" [0.8%]; CARGADOR S/LLANTAS 125-155 HP 3 YD3. [0.5%]; TRACTOR DE ORUGAS DE 190-240 HP [0.2%]; CHANCAD.PRIM.SECUND.5FAJAS 75HP 46-70 T/ [0.3%]; ZARANDA VIBRATORIA 4" x 6" x 14 M.E. 15 HP [0.4%]; LAVADORA DE AGREGADO [0.4%]; GRUPO ELECTROGENO 116 HP 75 KW [0.1%]; GRUPO ELECTROGENO 140HP 90 KW [0.7%]; CLAVOS [63 KG]; MADERA TORNILLO [1512 P2]; TRIPLAY DE 4´ x 8´ x 18 MM. [21 PLN]; PLANCHA DE ACERO 8.0 MM X 1.22 M X 2.40 M [42 und] | 129.8h | 2,642.6 | 08.11 | 000000000000089 | 21 | 1440.62 | 30253.02 |  |

| ID | WBS | Task | Duration | Start | Finish | Predecessors | Total slack | Free slack | Constraint | Resources | Work | Cost | Text1 | Text8 | Text2 | Text3 | Text4 | Text6 |
| --- | --- | --- | --- | --- | --- | --- | --- | --- | --- | --- | --- | --- | --- | --- | --- | --- | --- | --- |
| 98 | 1.9 | **PUENTE Y PONTONES** | 302d | 2012-04-16 | 2013-02-12 |  | 13d |  |  |  | 26525.5h | 531,342.62 | 09 | 000000000000090 |  |  |  |  |
| 99 | 1.9.1 | **ESTRIBOS** | 212d | 2012-04-17 | 2012-11-15 |  | 13d |  |  |  | 18934.8h | 398,222.82 | 09.01 | 000000000000091 |  |  |  |  |
| 100 | 1.9.1.1 | DEMOLICIÓN DE ESTRUCTURA EXISTENTE | 8d | 2012-04-17 | 2012-04-25 | 4SS+10d, 140 | 13d | 0d | start no earlier than 2011-09-30 | COMPRESORA NEUMATICA 250-330 PCM 87 HP [91.7%]; CAPATAZ [91.7%]; OFICIAL [366.9%]; PEON [366.9%]; EXCAVADORA SOBRE ORUGAS 115-165 HP 0.75 - 1.6 YD3 [91.7%]; MARTILLO NEUMATICO DE 29 Kg. [183.5%]; BARRENO 5' X 7/8" [10.57 und] | 763.04h | 24,196.47 | 09.01.01 | 000000000000092 | 440.25 | 63.36 | 27894.24 | 60 |
| 101 | 1.9.1.2 | EXCAVACION PARA ESTRUCTURAS EN ROCA EN SECO | 23d | 2012-05-02 | 2012-05-25 | 102 | 276d |  | start no earlier than 2011-09-30 | COMPRESORA NEUMATICA 250-330 PCM 87 HP [39%]; CAPATAZ [9.8%]; PEON [390.4%]; EXCAVADORA SOBRE LLANTAS 58 HP 1. YD3 [97.6%]; MARTILLO NEUMATICO DE 29 Kg. [78.1%]; DINAMITA [89.79 KG]; MECHA [44892.8%]; FULMINANTE [448.93 und]; BARRENO 5' X 7/8" [12.21 und] | 1131.3h | 31,533.78 | 09.01.02 | 000000000000093 | 1795.71 | 21.09 | 37871.52 | 80 |
| 102 | 1.9.1.3 | EXCAVACION PARA ESTRUCTURAS EN ROCA BAJO AGUA | 7d | 2012-04-25 | 2012-05-02 | 100 | 13d | 0d | start no earlier than 2011-09-30 | COMPRESORA NEUMATICA 250-330 PCM 87 HP [36.5%]; CAPATAZ [9.1%]; PEON [364.9%]; EXCAVADORA SOBRE LLANTAS 58 HP 1. YD3 [91.2%]; MARTILLO NEUMATICO DE 29 Kg. [73%]; MOTOBOMBA 34 HP 8" [91.2%]; DINAMITA [25.54 KG]; MECHA [12771.8%]; FULMINANTE [127.72 und]; BARRENO 5' X 7/8" [3.47 und] | 372.94h | 12,528.69 | 09.01.03 | 000000000000094 | 510.87 | 28.02 | 14314.58 | 80 |
| 103 | 1.9.1.4 | EXCAVACION PARA ESTRUCTURAS EN MATERIAL COMUN EN SECO | 7d | 2012-05-08 | 2012-05-15 | 104 | 286d |  | start no earlier than 2011-09-30 | COMPRESORA NEUMATICA 250-330 PCM 87 HP [26.1%]; CAPATAZ [8.7%]; PEON [347.9%]; EXCAVADORA SOBRE LLANTAS 58 HP 1. YD3 [87%]; MARTILLO NEUMATICO DE 29 Kg. [52.2%]; BARRENO 5' X 7/8" [0.12 und] | 292.25h | 8,413.9 | 09.01.04 | 000000000000191 | 608.86 | 13.5 | 8219.61 | 100 |
| 104 | 1.9.1.5 | EXCAVACION PARA ESTRUCTURAS EN MATERIAL COMUN BAJO AGUA | 6d | 2012-05-02 | 2012-05-08 | 102 | 286d | 0d | start no earlier than 2011-09-30 | COMPRESORA NEUMATICA 250-330 PCM 87 HP [27%]; CAPATAZ [9%]; PEON [360.3%]; EXCAVADORA SOBRE LLANTAS 58 HP 1. YD3 [90.1%]; MARTILLO NEUMATICO DE 29 Kg. [54%]; MOTOBOMBA 34 HP 8" [90.1%]; BARRENO 5' X 7/8" [0.11 und] | 302.65h | 10,296.92 | 09.01.05 | 000000000000142 | 540.44 | 19.05 | 10295.38 | 100 |
| 105 | 1.9.1.6 | RELLENOS PARA ESTRUCTURAS | 28d | 2012-10-18 | 2012-11-15 | 113FF+3d | 16d | 0d | start no earlier than 2011-09-30 | CAMION CISTERNA 4X2 3 000 GAL (INC MOTOBOMBA) [7.5%]; CAPATAZ [9.9%]; OFICIAL [99.3%]; PEON [305.5%]; COMPACTADOR TIPO PLANCHA 7 HP [198.6%]; RODILLO LISO VIBRATORIO MANUAL 10.8 HP 0.8-1.1 TON [99.3%] | 1613.29h | 31,615.96 | 09.01.06 | 000000000000143 | 2731.13 | 23.15 | 63225.66 | 50 |
| 106 | 1.9.1.7 | ACERO DE REFUERZO F'Y=4200 KG/CM2 | 116d | 2012-05-03 | 2012-08-27 | 118SS+1d | 13d | 0d | start no earlier than 2011-09-30 | CAPATAZ [10%]; OPERARIO; OFICIAL; PEON; ALAMBRE NEGRO NACIONAL # 16 [2897.26 KG]; ACERO CORRUGADO FY=4200 KG/CM2 GRADO 60 [60842.4 KG.] | 2874.08h | 38,031.25 | 09.01.07 | 000000000000096 | 57945.12 | 4.8 | 278136.58 | 250 |
| 107 | 1.9.1.8 | ENCOFRADO Y DESENCOFRADO CARA NO VISTA BAJO AGUA | 22d | 2012-05-08 | 2012-05-30 | 106SS+5d | 82d | 0d | start no earlier than 2011-09-30 | CAPATAZ [9.7%]; OPERARIO [96.7%]; OFICIAL [96.7%]; PEON [193.5%]; MOTOBOMBA 34 HP 8" [96.7%]; ALAMBRE NEGRO NACIONAL # 8 [59.6 KG]; CLAVOS [59.6 KG]; MADERA TORNILLO [1191.96 P2]; TRIPLAY DE 4´ x 8´ x 18 MM. [17.88 PLN] | 868.4h | 20,039.16 | 09.01.08 | 000000000000097 | 297.99 | 93.31 | 27805.45 | 14 |
| 108 | 1.9.1.9 | ENCOFRADO Y DESENCOFRADO CARA NO VISTA EN SECO | 31d | 2012-08-27 | 2012-09-27 | 106, 116 | 22d | 0d | start no earlier than 2011-09-30 | ADITIVO CURADOR [18.92 GLN]; CAPATAZ [9.7%]; OPERARIO [96.9%]; OFICIAL [96.9%]; PEON [193.8%]; ALAMBRE NEGRO NACIONAL # 8 [84.1 KG]; CLAVOS [84.1 KG]; MADERA TORNILLO [1682 P2]; TRIPLAY DE 4´ x 8´ x 18 MM. [25.23 PLN] | 985.15h | 12,743.7 | 09.01.09 | 000000000000144 | 420.5 | 53.76 | 22606.08 | 14 |
| 109 | 1.9.1.10 | ENCOFRADO Y DESENCOFRADO CARA VISTA BAJO AGUA | 18d | 2012-05-08 | 2012-05-26 | 106SS+5d | 86d | 0d | start no earlier than 2011-09-30 | DESMOLDANTE PARA MADERA [11.47 GLN]; CAPATAZ [9.6%]; OPERARIO [95.5%]; OFICIAL [95.5%]; PEON [191%]; MOTOBOMBA 34 HP 8" [95.5%]; ALAMBRE NEGRO NACIONAL # 8 [41.25 KG]; CLAVOS [41.25 KG]; MADERA TORNILLO [825.04 P2]; TRIPLAY DE 4´ x 8´ x 18 MM. [14.44 PLN] | 701.3h | 16,278.43 | 09.01.10 | 000000000000145 | 206.26 | 110.32 | 22754.6 | 12 |
| 110 | 1.9.1.11 | ENCOFRADO Y DESENCOFRADO CARA VISTA EN SECO | 37d | 2012-08-27 | 2012-10-03 | 106, 116 | 13d | 0d | start no earlier than 2011-09-30 | ADITIVO CURADOR [19.51 GLN]; DESMOLDANTE PARA MADERA [24.1 GLN]; CAPATAZ [9.8%]; OPERARIO [97.6%]; OFICIAL [97.6%]; PEON [195.3%]; ALAMBRE NEGRO NACIONAL # 8 [86.7 KG]; CLAVOS [86.7 KG]; MADERA TORNILLO [1733.96 P2]; TRIPLAY DE 4´ x 8´ x 18 MM. [30.34 PLN] | 1184.9h | 15,381.99 | 09.01.11 | 000000000000098 | 433.49 | 64.12 | 27795.38 | 12 |
| 111 | 1.9.1.12 | ENCOFRADO Y DESENCOFRADO CARA NO VISTA EN SECO(CURVOS) | 8d | 2012-09-27 | 2012-10-05 | 108 | 22d | 9d | start no earlier than 2011-09-30 | ADITIVO CURADOR [4.08 GLN]; DESMOLDANTE PARA MADERA [5.04 GLN]; CAPATAZ [18.9%]; OPERARIO [94.5%]; OFICIAL [94.5%]; PEON [189%]; ALAMBRE NEGRO NACIONAL # 8 [18.14 KG]; CLAVOS [18.14 KG]; MADERA TORNILLO [362.84 P2]; TRIPLAY DE 4´ x 8´ x 18 MM. [5.44 PLN] | 253.99h | 3,474.22 | 09.01.12 | 000000000000147 | 90.71 | 64.51 | 5851.7 | 12 |
| 112 | 1.9.1.13 | ENCOFRADO Y DESENCOFRADO CARA VISTA EN SECO(CURVOS) | 11d | 2012-10-03 | 2012-10-14 | 110 | 13d | 0d | start no earlier than 2011-09-30 | ADITIVO CURADOR [4.53 GLN]; DESMOLDANTE PARA MADERA [5.6 GLN]; CAPATAZ [18.3%]; OPERARIO [91.6%]; OFICIAL [91.6%]; PEON [183.2%]; ALAMBRE NEGRO NACIONAL # 8 [20.15 KG]; CLAVOS [20.15 KG]; MADERA TORNILLO [403.08 P2]; TRIPLAY DE 4´ x 8´ x 18 MM. [6.05 PLN] | 338.59h | 4,570.75 | 09.01.13 | 000000000000148 | 100.77 | 72.14 | 7269.55 | 10 |
| 113 | 1.9.1.14 | CONCRETO CLASE C (F´c = 280 Kg/cm2) | 4d | 2012-11-08 | 2012-11-12 | 115 | 13d | 0d | start no earlier than 2011-09-30 | CEMENTO PORTLAND TIPO I [667.15 BLS]; ADITIVO INCORPORADOR DE AIRE [8.76 GLN]; COMBUSTIBLE [16.98 GLN]; VOLQUETE DE 15 M3 [28.9%]; CAMION CISTERNA 4X2 3 000 GAL (INC MOTOBOMBA) [3.3%]; VIBRADOR DE 4 HP CAP.=1.25" [84.2%]; CAPATAZ [45.3%]; OPERARIO [260.8%]; OFICIAL [277.2%]; PEON [564.8%]; MEZCLADORA DE CONCRETO 11 P3 18 HP [84.2%]; MOTOBOMBA DIAM 4" [17.8%]; CARGADOR S/LLANTAS 125-155 HP 3 YD3. [10%]; TRACTOR DE ORUGAS DE 190-240 HP [3.6%]; CHANCAD.PRIM.SECUND.5FAJAS 75HP 46-70 T/ [6.9%]; ZARANDA VIBRATORIA 4" x 6" x 14 M.E. 15 HP [9.5%]; LAVADORA DE AGREGADO [8.1%]; GRUPO ELECTROGENO 116 HP 75 KW [2.6%]; GRUPO ELECTROGENO 140HP 90 KW [15%] | 455.12h | 10,120.44 | 09.01.14 | 000000000000149 | 60.65 | 392.07 | 23779.05 | 18 |
| 114 | 1.9.1.15 | CONCRETO CLASE C1 (F´c = 280 Kg/cm2) BAJO AGUA | 3d | 2012-06-19 | 2012-06-22 | 116 | 248d |  | start no earlier than 2011-09-30 | CEMENTO PORTLAND TIPO I [422.95 BLS]; ADITIVO INCORPORADOR DE AIRE [12.83 GLN]; COMBUSTIBLE [10.77 GLN]; VOLQUETE DE 15 M3 [24.4%]; CAMION CISTERNA 4X2 3 000 GAL (INC MOTOBOMBA) [2.8%]; VIBRADOR DE 4 HP CAP.=1.25" [80.1%]; CAPATAZ [42.7%]; OPERARIO [247.2%]; OFICIAL [261%]; PEON [530.8%]; MEZCLADORA DE CONCRETO 11 P3 18 HP [80.1%]; MOTOBOMBA DIAM 4" [15.1%]; CARGADOR S/LLANTAS 125-155 HP 3 YD3. [8.5%]; TRACTOR DE ORUGAS DE 190-240 HP [3%]; CHANCAD.PRIM.SECUND.5FAJAS 75HP 46-70 T/ [5.8%]; ZARANDA VIBRATORIA 4" x 6" x 14 M.E. 15 HP [8%]; MOTOBOMBA 34 HP 8" [80.1%]; LAVADORA DE AGREGADO [6.9%]; GRUPO ELECTROGENO 116 HP 75 KW [2.2%]; GRUPO ELECTROGENO 140HP 90 KW [12.7%] | 338.73h | 8,054.94 | 09.01.15 | 000000000000150 | 38.45 | 450.04 | 17304.04 | 16 |
| 115 | 1.9.1.16 | CONCRETO CLASE D (F´c = 210 Kg/cm2) | 25d | 2012-10-14 | 2012-11-08 | 111, 112, 116 | 13d | 0d | start no earlier than 2011-09-30 | CEMENTO PORTLAND TIPO I [3916.8 BLS]; ADITIVO INCORPORADOR DE AIRE [51.44 GLN]; COMBUSTIBLE [121.86 GLN]; VOLQUETE DE 15 M3 [33.2%]; CAMION CISTERNA 4X2 3 000 GAL (INC MOTOBOMBA) [3.7%]; VIBRADOR DE 4 HP CAP.=1.25" [96.7%]; CAPATAZ [52%]; OPERARIO [299.4%]; OFICIAL [318.3%]; PEON [648.5%]; MEZCLADORA DE CONCRETO 11 P3 18 HP [96.7%]; MOTOBOMBA DIAM 4" [20.5%]; CARGADOR S/LLANTAS 125-155 HP 3 YD3. [11.5%]; TRACTOR DE ORUGAS DE 190-240 HP [4.1%]; CHANCAD.PRIM.SECUND.5FAJAS 75HP 46-70 T/ [7.9%]; ZARANDA VIBRATORIA 4" x 6" x 14 M.E. 15 HP [10.9%]; LAVADORA DE AGREGADO [9.3%]; GRUPO ELECTROGENO 116 HP 75 KW [3%]; GRUPO ELECTROGENO 140HP 90 KW [17.2%] | 3265.76h | 72,247.25 | 09.01.16 | 000000000000151 | 435.2 | 352.26 | 153303.55 | 18 |
| 116 | 1.9.1.17 | CONCRETO CLASE D1 (F´c = 210 Kg/cm2) BAJO AGUA | 20d | 2012-05-30 | 2012-06-19 | 107, 109 | 82d | 0d | start no earlier than 2011-09-30 | CEMENTO PORTLAND TIPO I [3115.89 BLS]; ADITIVO INCORPORADOR DE AIRE [94.55 GLN]; COMBUSTIBLE [96.94 GLN]; VOLQUETE DE 15 M3 [33%]; CAMION CISTERNA 4X2 3 000 GAL (INC MOTOBOMBA) [3.7%]; VIBRADOR DE 4 HP CAP.=1.25" [96.2%]; CAPATAZ [51.7%]; OPERARIO [297.8%]; OFICIAL [316.5%]; PEON [644.8%]; MEZCLADORA DE CONCRETO 11 P3 18 HP [96.2%]; MOTOBOMBA DIAM 4" [20.4%]; CARGADOR S/LLANTAS 125-155 HP 3 YD3. [11.4%]; TRACTOR DE ORUGAS DE 190-240 HP [4.1%]; CHANCAD.PRIM.SECUND.5FAJAS 75HP 46-70 T/ [7.8%]; ZARANDA VIBRATORIA 4" x 6" x 14 M.E. 15 HP [10.8%]; MOTOBOMBA 34 HP 8" [96.2%]; LAVADORA DE AGREGADO [9.3%]; GRUPO ELECTROGENO 116 HP 75 KW [3%]; GRUPO ELECTROGENO 140HP 90 KW [17.1%] | 2751.83h | 67,411.7 | 09.01.17 | 000000000000152 | 346.21 | 394.23 | 136486.37 | 18 |
| 117 | 1.9.1.18 | CONCRETO CLASE F1 (F´c = 100 Kg/cm2 ) | 2d | 2012-05-04 | 2012-05-06 | 118 | 295d |  | start no earlier than 2011-09-30 | CEMENTO PORTLAND TIPO I [180.18 BLS]; ADITIVO INCORPORADOR DE AIRE [2.37 GLN]; COMBUSTIBLE [11.21 GLN]; VOLQUETE DE 15 M3 [38.2%]; CAMION CISTERNA 4X2 3 000 GAL (INC MOTOBOMBA) [4.3%]; VIBRADOR DE 4 HP CAP.=1.25" [80.1%]; CAPATAZ [44.2%]; OPERARIO [251%]; OFICIAL [272.6%]; PEON [558.9%]; MEZCLADORA DE CONCRETO 11 P3 18 HP [80.1%]; MOTOBOMBA DIAM 4" [23.6%]; CARGADOR S/LLANTAS 125-155 HP 3 YD3. [13.2%]; TRACTOR DE ORUGAS DE 190-240 HP [4.8%]; CHANCAD.PRIM.SECUND.5FAJAS 75HP 46-70 T/ [9.1%]; ZARANDA VIBRATORIA 4" x 6" x 14 M.E. 15 HP [12.5%]; LAVADORA DE AGREGADO [10.7%]; GRUPO ELECTROGENO 116 HP 75 KW [3.4%]; GRUPO ELECTROGENO 140HP 90 KW [19.8%] | 228.22h | 5,823.49 | 09.01.18 | 000000000000153 | 40.04 | 239.63 | 9594.79 | 25 |
| 118 | 1.9.1.19 | CONCRETO CLASE F2 (F´c = 100 Kg/cm2 ) BAJO AGUA | 2d | 2012-05-02 | 2012-05-04 | 102 | 13d | 0d | start no earlier than 2011-09-30 | CEMENTO PORTLAND TIPO I [132.16 BLS]; ADITIVO INCORPORADOR DE AIRE [4.01 GLN]; COMBUSTIBLE [8.22 GLN]; VOLQUETE DE 15 M3 [28%]; CAMION CISTERNA 4X2 3 000 GAL (INC MOTOBOMBA) [3.2%]; VIBRADOR DE 4 HP CAP.=1.25" [73.4%]; CAPATAZ [39.8%]; OPERARIO [228.1%]; OFICIAL [244%]; PEON [498.1%]; MEZCLADORA DE CONCRETO 11 P3 18 HP [73.4%]; MOTOBOMBA DIAM 4" [17.3%]; CARGADOR S/LLANTAS 125-155 HP 3 YD3. [9.7%]; TRACTOR DE ORUGAS DE 190-240 HP [3.5%]; CHANCAD.PRIM.SECUND.5FAJAS 75HP 46-70 T/ [6.6%]; ZARANDA VIBRATORIA 4" x 6" x 14 M.E. 15 HP [9.2%]; MOTOBOMBA 34 HP 8" [73.4%]; LAVADORA DE AGREGADO [7.9%]; GRUPO ELECTROGENO 116 HP 75 KW [2.5%]; GRUPO ELECTROGENO 140HP 90 KW [14.5%] | 213.22h | 5,459.79 | 09.01.19 | 000000000000154 | 29.37 | 290.35 | 8527.58 | 20 |
| 119 | 1.9.2 | **LOSAS Y VEREDAS** | 84d | 2012-11-15 | 2013-02-07 |  | 13d |  |  |  | 3856.51h | 61,234.81 | 09.02 | 000000000000113 |  |  |  |  |
| 120 | 1.9.2.1 | ENCOFRADO Y DESENCOFRADO CARA NO VISTA TABLERO | 8d | 2012-11-15 | 2012-11-23 | 113, 115, 133, 142 | 13d | 0d | start no earlier than 2011-09-30 | ADITIVO CURADOR [8.96 GLN]; DESMOLDANTE PARA MADERA [11.07 GLN]; CAPATAZ [19%]; OPERARIO [94.8%]; OFICIAL [94.8%]; PEON [189.6%]; ALAMBRE NEGRO NACIONAL # 8 [39.82 KG]; CLAVOS [39.82 KG]; MADERA TORNILLO [1194.48 P2]; TRIPLAY DE 4´ x 8´ x 18 MM. [11.94 PLN] | 254.82h | 3,485.04 | 09.02.01 | 000000000000115 | 199.08 | 66.7 | 13278.64 | 14 |
| 121 | 1.9.2.2 | ENCOFRADO Y DESENCOFRADO CARA VISTA TABLERO | 7d | 2012-11-15 | 2012-11-22 | 113, 115, 133, 142 | 14d | 0d | start no earlier than 2011-09-30 | ADITIVO CURADOR [7.24 GLN]; DESMOLDANTE PARA MADERA [8.95 GLN]; CAPATAZ [19.2%]; OPERARIO [95.8%]; OFICIAL [95.8%]; PEON [191.6%]; ALAMBRE NEGRO NACIONAL # 8 [32.19 KG]; CLAVOS [32.19 KG]; MADERA TORNILLO [965.76 P2]; TRIPLAY DE 4´ x 8´ x 18 MM. [11.27 PLN] | 225.34h | 3,102.95 | 09.02.02 | 000000000000155 | 160.96 | 73.03 | 11754.91 | 12 |
| 122 | 1.9.2.3 | ENCOFRADO Y DESENCOFRADO LOSA DE TRANSICION | 5d | 2012-11-15 | 2012-11-20 | 105 | 16d | 3d | start no earlier than 2011-09-30 | ADITIVO CURADOR [2.74 GLN]; DESMOLDANTE PARA MADERA [3.39 GLN]; CAPATAZ [16.2%]; OPERARIO [81.2%]; OFICIAL [81.2%]; PEON [162.4%]; ALAMBRE NEGRO NACIONAL # 8 [12.18 KG]; CLAVOS [12.18 KG]; MADERA TORNILLO [365.4 P2]; TRIPLAY DE 4´ x 8´ x 18 MM. [4.26 PLN] | 136.42h | 1,950.33 | 09.02.03 | 000000000000156 | 60.9 | 65.42 | 3984.08 | 15 |
| 123 | 1.9.2.4 | ENCOFRADO Y DESENCOFRADO CARA VISTA EN BARRERA | 5d | 2013-02-02 | 2013-02-07 | 127 | 18d |  | start no earlier than 2011-09-30 | ADITIVO CURADOR [4.08 GLN]; DESMOLDANTE PARA MADERA [5.04 GLN]; CAPATAZ [18.1%]; OPERARIO [90.6%]; OFICIAL [90.6%]; PEON [181.2%]; ALAMBRE NEGRO NACIONAL # 8 [18.12 KG]; CLAVOS [18.12 KG]; MADERA TORNILLO [543.54 P2]; TRIPLAY DE 4´ x 8´ x 18 MM. [6.34 PLN] | 152.19h | 2,154.8 | 09.02.04 | 000000000000157 | 90.59 | 80.66 | 7306.99 | 10 |
| 124 | 1.9.2.5 | ENCOFRADO Y DESENCOFRADO CARA VISTA EN VEREDA Y PARAPETO | 3d | 2013-02-02 | 2013-02-05 | 127 | 20d |  | start no earlier than 2011-09-30 | ADITIVO CURADOR [1.45 GLN]; DESMOLDANTE PARA MADERA [1.8 GLN]; CAPATAZ [17.9%]; OPERARIO [89.7%]; OFICIAL [89.7%]; PEON [179.4%]; ALAMBRE NEGRO NACIONAL # 8 [6.46 KG]; CLAVOS [6.46 KG]; MADERA TORNILLO [193.8 P2]; TRIPLAY DE 4´ x 8´ x 18 MM. [2.26 PLN] | 90.44h | 1,354.41 | 09.02.05 | 000000000000159 | 32.3 | 73.03 | 2358.87 | 12 |
| 125 | 1.9.2.6 | ENCOFRADO Y DESENCOFRADO CARA VISTA EN VIGA PRINCIPAL Y DIAFRAGMA | 11d | 2012-11-15 | 2012-11-26 | 113, 115, 133, 142 | 91d |  | start no earlier than 2011-09-30 | ADITIVO CURADOR [9.76 GLN]; DESMOLDANTE PARA MADERA [12.05 GLN]; CAPATAZ [19.7%]; OPERARIO [98.5%]; OFICIAL [98.5%]; PEON [197.1%]; ALAMBRE NEGRO NACIONAL # 8 [43.36 KG]; CLAVOS [43.36 KG]; MADERA TORNILLO [1300.86 P2]; TRIPLAY DE 4´ x 8´ x 18 MM. [15.18 PLN] | 364.24h | 4,903.26 | 09.02.06 | 000000000000160 | 216.81 | 80.66 | 17487.89 | 10 |
| 126 | 1.9.2.7 | ACERO DE REFUERZO F'Y=4200 KG/CM2 | 64d | 2012-11-23 | 2013-01-26 | 120, 121, 122 | 13d | 0d | start no earlier than 2011-09-30 | CAPATAZ [10%]; OPERARIO; OFICIAL; PEON; ALAMBRE NEGRO NACIONAL # 16 [1582.98 KG]; ACERO CORRUGADO FY=4200 KG/CM2 GRADO 60 [33242.7 KG.] | 1582.69h | 20,945.71 | 09.02.07 | 000000000000114 | 31659.69 | 4.8 | 151966.51 | 250 |
| 127 | 1.9.2.8 | CONCRETO CLASE C (F´c = 280 Kg/cm2) LOSA,LOSA TRANSICION Y VIGA(PRINCIPAL Y DIAFRAGMA) | 7d | 2013-01-26 | 2013-02-02 | 122, 126 | 13d | 0d | start no earlier than 2011-09-30 | CEMENTO PORTLAND TIPO I [2533.63 BLS]; ADITIVO INCORPORADOR DE AIRE [76.88 GLN]; COMBUSTIBLE [64.49 GLN]; VOLQUETE DE 15 M3 [33.8%]; CAMION CISTERNA 4X2 3 000 GAL (INC MOTOBOMBA) [3.8%]; VIBRADOR DE 4 HP CAP.=1.25" [98.4%]; CAPATAZ [52.9%]; OPERARIO [304.8%]; OFICIAL [323.9%]; PEON [660%]; MEZCLADORA DE CONCRETO 11 P3 18 HP [98.4%]; MOTOBOMBA DIAM 4" [20.9%]; CARGADOR S/LLANTAS 125-155 HP 3 YD3. [11.7%]; TRACTOR DE ORUGAS DE 190-240 HP [4.2%]; CHANCAD.PRIM.SECUND.5FAJAS 75HP 46-70 T/ [8%]; ZARANDA VIBRATORIA 4" x 6" x 14 M.E. 15 HP [11.1%]; LAVADORA DE AGREGADO [9.5%]; GRUPO ELECTROGENO 116 HP 75 KW [3%]; GRUPO ELECTROGENO 140HP 90 KW [17.5%] | 930.68h | 20,632.32 | 09.02.08 | 000000000000161 | 230.33 | 397.81 | 91627.58 | 18 |
| 128 | 1.9.2.9 | CONCRETO CLASE D (F´c = 210 Kg/cm2) EN VEREDA, PARAPETO Y BARRERA | 1d | 2013-02-03 | 2013-02-04 | 127, 136 | 13d | 0d | start no earlier than 2011-09-30 | CEMENTO PORTLAND TIPO I [143.55 BLS]; ADITIVO INCORPORADOR DE AIRE [4.36 GLN]; COMBUSTIBLE [4.47 GLN]; VOLQUETE DE 15 M3 [30.4%]; CAMION CISTERNA 4X2 3 000 GAL (INC MOTOBOMBA) [3.4%]; VIBRADOR DE 4 HP CAP.=1.25" [88.6%]; CAPATAZ [47.6%]; OPERARIO [274.4%]; OFICIAL [291.6%]; PEON [594.2%]; MEZCLADORA DE CONCRETO 11 P3 18 HP [88.6%]; MOTOBOMBA DIAM 4" [18.8%]; CARGADOR S/LLANTAS 125-155 HP 3 YD3. [10.5%]; TRACTOR DE ORUGAS DE 190-240 HP [3.8%]; CHANCAD.PRIM.SECUND.5FAJAS 75HP 46-70 T/ [7.2%]; ZARANDA VIBRATORIA 4" x 6" x 14 M.E. 15 HP [10%]; LAVADORA DE AGREGADO [8.5%]; GRUPO ELECTROGENO 116 HP 75 KW [2.7%]; GRUPO ELECTROGENO 140HP 90 KW [15.8%] | 119.69h | 2,706 | 09.02.09 | 000000000000162 | 15.95 | 356.95 | 5693.35 | 18 |

| ID | WBS | Task | Duration | Start | Finish | Predecessors | Total slack | Free slack | Constraint | Resources | Work | Cost | Text1 | Text8 | Text2 | Text3 | Text4 | Text6 |
| --- | --- | --- | --- | --- | --- | --- | --- | --- | --- | --- | --- | --- | --- | --- | --- | --- | --- | --- |
| 129 | 1.9.3 | **VARIOS** | 302d | 2012-04-16 | 2013-02-12 |  | 13d |  |  |  | 3734.24h | 71,884.99 | 09.03 | 000000000000119 |  |  |  |  |
| 130 | 1.9.3.1 | JUNTA DE DILATACION ENTRE LOSA DE TRANSICION Y ESTRIBO | 1d | 2013-02-04 | 2013-02-05 | 127, 128 | 20d |  | start no earlier than 2011-09-30 | IMPRIMANTE PARA SELLANTES JUNTAS [0.21 GLN]; SELLADOR DE JUNTAS [2.41 GLN]; CAPATAZ [3.3%]; OPERARIO [32.5%]; OFICIAL [32.5%]; PEON [32.5%]; CORDON DE RESPALDO PARA EL SELLADO DE JUNTAS 7/8" [6509%]; TECNOPOR DE 3/4" [32.35 M2] | 8.07h | 495.7 | 09.03.01 | 000000000000120 | 65.09 | 10.47 | 681.49 | 200 |
| 131 | 1.9.3.2 | JUNTA DE DILATACION ENTRE LOSA Y ESTRIBO | 1d | 2013-02-04 | 2013-02-05 | 127, 128 | 20d |  | start no earlier than 2011-09-30 | IMPRIMANTE PARA SELLANTES JUNTAS [0.15 GLN]; SELLADOR DE JUNTAS [4.1 GLN]; CAPATAZ [9%]; OPERARIO [90.1%]; OFICIAL [90.1%]; PEON [90.1%]; BARRA LISA 1/2" [25693.2%]; NEOPRENO EXPANDIBLE-COMPRESIBLE TIPO PANAL 5cm x 7cm [4506%]; PERFIL 4" x 4" x 1/2" [9012%]; PERFIL 3/8" x 1" x 3/16" [9012%] | 22.35h | 824.78 | 09.03.02 | 000000000000173 | 45.06 | 260.87 | 11754.8 | 50 |
| 132 | 1.9.3.3 | DISPOSITIVO DE APOYOS P/POTRERILLO | 2d | 2012-11-12 | 2012-11-14 | 113, 115 | 103d |  | start no earlier than 2011-09-30 | CAPATAZ [10%]; OPERARIO; OFICIAL; PEON; RELLENO CON GROUT [200.77 KG]; NEOPRENO 260mm x 400mm x 75mm C/LAMINAS A-36 DE 3mm [10 und] | 49.6h | 902.34 | 09.03.03 | 000000000000122 | 10 | 363.29 | 3632.9 |  |
| 133 | 1.9.3.4 | DISPOSITIVO DE APOYOS RIO COLORADO | 3d | 2012-11-12 | 2012-11-15 | 113, 115 | 13d | 0d | start no earlier than 2011-09-30 | CAPATAZ [8.3%]; OPERARIO [83.3%]; OFICIAL [83.3%]; PEON [83.3%]; RELLENO CON GROUT [155.97 KG]; ACERO CORRUGADO FY=4200 KG/CM2 GRADO 60 [59.55 KG.]; TUBERIA PVC DIAM 2" [1500%]; NEOPRENO 150mm x 500mm x 35mm C/LAMINAS A-36 DE 2mm [10 und] | 62h | 939.43 | 09.03.04 | 000000000000174 | 10 | 259.71 | 2597.1 |  |
| 134 | 1.9.3.5 | SUMIDERO | 1d | 2012-11-21 | 2012-11-22 | 121FF | 95d |  | start no earlier than 2011-09-30 | CAPATAZ [3.3%]; OPERARIO [33.3%]; PEON [16.7%]; TUBO DE F°G° 4" [400%]; REJILLA CIRCULAR DE METAL DIAM 20cm [5 und] | 4.27h | 210.18 | 09.03.05 | 000000000000121 |  | 153.13 | 765.65 | 15 |
| 135 | 1.9.3.6 | TUBO PVC SAP D=4" | 1d | 2012-05-08 | 2012-05-09 | 107SS, 109SS | 292d |  | start no earlier than 2011-09-30 | CAPATAZ [5%]; OPERARIO [50%]; PEON [50%]; TUBERIA PVC DIAM 4" [600%] | 8.4h | 127.92 | 09.03.06 | 000000000000163 |  | 36.46 | 218.76 | 12 |
| 136 | 1.9.3.7 | TUBO DE PVC SAP D=6" | 1d | 2013-02-02 | 2013-02-03 | 127 | 13d | 0d | start no earlier than 2011-09-30 | CAPATAZ [2.9%]; OPERARIO [29.1%]; PEON [29.1%]; TUBERIA PVC DIAM 6" [3055.5%] | 4.89h | 99.19 | 09.03.07 | 000000000000164 | 29.1 | 41.18 | 1198.34 | 100 |
| 137 | 1.9.3.8 | TUBERIA CORRUGADA PERFORADA HDPE, D=6" | 1d | 2012-11-23 | 2012-11-24 | 144 | 92d | 0d | start no earlier than 2011-09-30 | CAPATAZ [7.3%]; OPERARIO [72.7%]; PEON [72.7%]; TUBERIA CORRUGADA PERFORADA HDPE DIAM 6"X19' [6870.1%]; UNION SPLIT 6" [10.76 und] | 12.22h | 192.11 | 09.03.08 | 000000000000124 | 65.43 | 24.74 | 1618.74 | 90 |
| 138 | 1.9.3.9 | RIEGO DE LIGA | 1d | 2013-02-02 | 2013-02-03 | 127 | 22d |  | start no earlier than 2011-09-30 | COMPRESORA NEUMATICA 250-330 PCM 87 HP [13.5%]; CAMION IMPRIMADOR DE 1800 GLS. [13.5%]; CAPATAZ [13.5%]; PEON [80.5%]; MINICARGADOR 70 HP [13.5%] | 10.78h | 377.92 | 09.03.09 | 000000000000125 | 602.09 | 0.63 | 379.32 | 4500 |
| 139 | 1.9.3.10 | EMULSION ASFALTICA DE ROTURA RAPIDA CRS-2 | 1d | 2013-02-02 | 2013-02-03 | 127 | 22d |  | start no earlier than 2011-09-30 | EMULSION ASFALTICA DE ROTURA RAPIDA CRS-2 [270.94 LT] |  | 2.71 | 09.03.10 | 000000000000126 | 270.94 | 2.71 | 734.25 |  |
| 140 | 1.9.3.11 | PASE PROVISIONAL EN PONTONES | 1d | 2012-04-16 | 2012-04-17 | 4SS+15d | 13d | 0d | start no earlier than 2011-09-30 | CAMION CISTERNA 4X2 3 000 GAL (INC MOTOBOMBA) [55.6%]; COMPRESORA NEUMATICA 250-330 PCM 87 HP [494%]; CAPATAZ [184.5%]; OPERARIO [50%]; OFICIAL [585.5%]; PEON [7487.4%]; COMPACTADOR TIPO PLANCHA 7 HP [1171%]; EXCAVADORA SOBRE ORUGAS 115-165 HP 0.75 - 1.6 YD3 [6.2%]; EXCAVADORA SOBRE LLANTAS 58 HP 1. YD3 [1234.9%]; RODILLO LISO VIBRATORIO MANUAL 10.8 HP 0.8-1.1 TON [585.5%]; MARTILLO NEUMATICO DE 29 Kg. [987.9%]; DINAMITA [49.4 KG]; ALCANTARILLA METALICA DIAM 72" [5454.4%]; MECHA [24698.5%]; FULMINANTE [246.99 und]; BARRENO 5' X 7/8" [6.72 und] | 1027.42h | 26,240.39 | 09.03.11 | 000000000000165 |  | 43137.95 | 86275.9 |  |
| 141 | 1.9.3.12 | PASE PROVISIONAL EN POTRERILLO | 1d | 2012-05-02 | 2012-05-03 | 140FS+15d | 298d |  | start no earlier than 2011-09-30 | CEMENTO PORTLAND TIPO I [480 BLS]; ADITIVO INCORPORADOR DE AIRE [6.3 GLN]; COMBUSTIBLE [17.92 GLN]; VOLQUETE DE 15 M3 [122%]; CAMION CISTERNA 4X2 3 000 GAL (INC MOTOBOMBA) [18.3%]; COMPRESORA NEUMATICA 250-330 PCM 87 HP [20.2%]; VIBRADOR DE 4 HP CAP.=1.25" [355.5%]; CAPATAZ [212.1%]; OPERARIO [1300.9%]; OFICIAL [1230.3%]; PEON [3371.2%]; MEZCLADORA DE CONCRETO 11 P3 18 HP [355.5%]; MOTOBOMBA DIAM 4" [75.3%]; COMPACTADOR TIPO PLANCHA 7 HP [120.3%]; CARGADOR S/LLANTAS 125-155 HP 3 YD3. [42.3%]; TRACTOR DE ORUGAS DE 190-240 HP [15.2%]; EXCAVADORA SOBRE LLANTAS 58 HP 1. YD3 [50.5%]; RODILLO LISO VIBRATORIO MANUAL 10.8 HP 0.8-1.1 TON [60.2%]; MARTILLO NEUMATICO DE 29 Kg. [40.4%]; CHANCAD.PRIM.SECUND.5FAJAS 75HP 46-70 T/ [29%]; ZARANDA VIBRATORIA 4" x 6" x 14 M.E. 15 HP [40%]; LAVADORA DE AGREGADO [34.2%]; GRUPO ELECTROGENO 116 HP 75 KW [11%]; GRUPO ELECTROGENO 140HP 90 KW [63.2%]; CLAVOS [6.65 KG]; DINAMITA [2.02 KG]; MECHA [1010.2%]; MADERA TORNILLO [14404 P2]; PERNOS 5/8" X 6" [156 und]; FULMINANTE [10.1 und]; BARRENO 5' X 7/8" [0.27 und]; PLANCHA DE ACERO 6 MM X 1.22 M X 2.40 M [1.9 und] | 605.42h | 13,661.08 | 09.03.12 | 000000000000176 |  | 79139.83 | 79139.83 |  |
| 142 | 1.9.3.13 | FALSO PUENTE | 16d | 2012-04-25 | 2012-05-11 | 100 | 201d | 188d | start no earlier than 2011-09-30 | CAPATAZ [96.6%]; OPERARIO [193.1%]; OFICIAL [193.1%]; PEON [386.2%]; CLAVOS [154.5 KG]; MADERA TORNILLO [4635 P2] | 1112.4h | 14,831.73 | 09.03.13 | 000000000000166 | 30.9 | 1091.95 | 33741.26 |  |
| 143 | 1.9.3.14 | GEOCOMPUESTO DE DRENAJE TRIDIMENSIONAL | 1d | 2012-11-24 | 2012-11-25 | 137 | 92d |  | start no earlier than 2011-09-30 | CAPATAZ [8.8%]; OPERARIO [88.3%]; PEON [88.3%]; GEOCOMPUESTO DE DRENAJE [388.52 M2] | 14.83h | 217.25 | 09.03.14 | 000000000000167 | 353.2 | 20.65 | 7293.58 | 400 |
| 144 | 1.9.3.15 | PINTURA BITUMINOSA | 11d | 2012-11-12 | 2012-11-23 | 113, 115 | 92d | 0d | start no earlier than 2011-09-30 | PINTURA BITUMINOSA [139.57 GLN]; IMPRIMANTE P/EPOXICO [29.24 GLN]; DISOLVENTE DE PINTURA [24.76 GLN]; CAPATAZ [18.5%]; OPERARIO [185.2%]; OFICIAL [92.6%]; PEON [185.2%] | 423.81h | 6,125.88 | 09.03.15 | 000000000000168 | 1018.77 | 29.5 | 30053.72 | 100 |
| 145 | 1.9.3.16 | BARANDAS METALICAS | 6d | 2013-02-06 | 2013-02-12 | 127FS+2d, 128FS+2d | 13d |  | start no earlier than 2011-09-30 | PINTURA ESMALTE SINTETICO [4.87 GLN]; PINTURA ZINCROMATO [2.43 GLN]; THINNER STANDARD [4.46 GLN]; VOLQUETE DE 15 M3 [0%]; MOTOSOLDADORA 250 A [46.6%]; EQUIPO DE OXICORTE [46.6%]; COMPRESORA NEUMATICA 250-330 PCM 87 HP [10.3%]; CAPATAZ [23.1%]; OPERARIO [116%]; OFICIAL [8.1%]; PEON [414.3%]; ANDAMIOS [8.1%]; EQUIPO PARA ARENAR [2.2%]; MOTOBOMBA DIAM 4" [0%]; CARGADOR S/LLANTAS 125-155 HP 3 YD3. [0%]; TRACTOR DE ORUGAS DE 190-240 HP [0%]; ZARANDA VIBRATORIA 4" x 6" x 14 M.E. 15 HP [0%]; LAVADORA DE AGREGADO [0%]; GRUPO ELECTROGENO 116 HP 75 KW [0%]; GRUPO ELECTROGENO 140HP 90 KW [0%]; EQUIPO DE PINTURA [8.1%]; SOLDADURA E7018 [40.3 KG]; ACERO CORRUGADO FY=4200 KG/CM2 GRADO 60 [631.4 KG.]; TUBO DE FIERRO 3" [6717%]; TUBO DE FIERRO 2" [6717%]; ACETILENO [13.43 M3]; OXIGENO [40.3 M3] | 328.11h | 5,144.62 | 09.03.16 | 000000000000192 | 67.17 | 164.18 | 11027.97 | 12 |
| 146 | 1.9.3.17 | TOPE SISMICO | 2d | 2013-02-02 | 2013-02-04 | 127FF, 128FF | 21d |  | start no earlier than 2011-09-30 | CAPATAZ [8%]; OPERARIO [80%]; OFICIAL [80%]; PEON [80%]; SOLDADURA E7018 [0.08 KG]; BARRA LISA 1/2" [1680%]; NEOPRENO 250mm x 250mm x 30mm C/LAMINAS A-36 DE 3mm [8 und]; PLANCHA DE ACERO 12.5 MM X 1.22 M X 2.40 M [0.46 und] | 39.68h | 1,491.75 | 09.03.17 | 000000000000194 |  | 192.05 | 1536.4 |  |
